# SUBPROYECTO A2 - TRAMO 1

How a schedule from Primavera P6 changed from version to version. A marks actual dates.

## Version 1 (data date 2023-11-15, saved 2023-10-22, file PER2305-4 A2 -T1 rev 04.xer)

| ID | WBS | Task | Duration | Start | Finish | Predecessors | Total float |
| --- | --- | --- | --- | --- | --- | --- | --- |
|  | 0 | **HITOS** |  | 2023-11-15 | 2025-03-01 |  |  |
| A1000 |  | KICK OFF MEETING | 0d | 2023-11-15 | 2023-11-15 |  | 0d |
| A1010 |  | INICIO DE PLAZO CONTRACTUAL - ACCESO AL SITIO | 0d | 2023-12-01 | 2023-12-01 | A1000 SS+14d | 0d |
| A1015 |  | INICIO DE EXCAVACIÓN | 0d | 2023-12-06 | 2023-12-06 | A1010 SS+4d | 259d |
| A1016 |  | INICIO DE RELLENO DE DIQUE | 0d | 2023-12-28 | 2023-12-28 | A1015 SS+19d | 369d |
| A1020 |  | FIN DEL SERVICIO | 0d | 2025-03-01 | 2025-03-01 | A1200, A1780 FF, A1070, A1050, A4710 FF, A1730 FF, A7170 FF, A7190 FF, A7220 FF, A7230 FF, A7200 FF, A7210 FF, A7240 FF, A7250 FF, A7260 FF, A7270 FF, A4000 FF, A4650 FF, A1150 SF, A1870 FF, A7740 FF, A7630 FF, A8160 FF, A8490 FF, A1080 | 0d |
|  | 1 | **TRABAJOS INICIALES** |  | 2023-12-01 | 2025-03-01 |  |  |
|  | 1 | **OBRAS PRELIMINARES** |  | 2023-12-01 | 2024-05-28 |  |  |
| A1030 |  | CARTEL DE IDENTIFICACIÓN OBRA 4.80 x 3.60 m. | 2d | 2023-12-01 | 2023-12-02 | A1010 SS | 0d |
| A1040 |  | INSTALACIONES PROVISIONALES PARA LA OBRA | 4d | 2023-12-01 | 2023-12-05 | A1010 SS, A1030 SS | 0d |
| A1050 |  | MANTENIMIENTO DE TRÁNSITO Y SEGURIDAD VIAL | 154d | 2023-12-01 | 2024-05-28 | A1010 SS | 238d |
|  | 2 | **TRABAJOS PRELIMINARES** |  | 2023-12-01 | 2025-03-01 |  |  |
| A1060 |  | MOVILIZACION DE EQUIPOS | 4d | 2023-12-01 | 2023-12-05 | A1010 | 0d |
| A1070 |  | TOPOGRAFÍA Y GEOREFERENCIACIÓN | 387d | 2023-12-06 | 2025-02-28 | A1040 | 1d |
| A1080 |  | DESMOVILIZACION DE EQUIPOS | 7d | 2025-02-22 | 2025-03-01 | A1770 | 0d |
|  | 3 | **MEJORAMIENTO DE VÍAS EXISTENTES** |  | 2023-12-06 | 2025-02-03 |  |  |
|  | 1 | **MOVIMIENTO DE TIERRAS** |  | 2023-12-06 | 2024-05-03 |  |  |
| A1090 |  | ROCE Y LIMPIEZA DE MALEZA | 30d | 2023-12-06 | 2024-01-09 | A1015, A1060 | 259d |
| A1100 |  | REHABILITACIÓN DE VÍAS EXISTENTES | 129d | 2023-12-06 | 2024-05-03 | A1090 SS, A1050 SS+1d | 259d |
| A4650 |  | CONFORMACIÓN DE TERRAPLENES EN CAMINO | 30d | 2023-12-08 | 2024-01-11 | A1100 SS+2d | 356d |
|  | 2 | **REPOSICIÓN DE ESTRUCTURAS** |  | 2023-12-07 | 2025-01-22 |  |  |
| A1150 |  | DEMOLICIÓN DE ESTRUCTURAS EXISTENTES | 2d | 2023-12-07 | 2023-12-08 | A7430 SS | 385d |
| A1160 |  | REPOSICIÓN DE PASE DE AGUA TUBO HDPE Ø=18" | 2d | 2025-01-17 | 2025-01-18 | A8440 SS | 23d |
| A1170 |  | REPOSICIÓN DE PASE DE AGUA TUBO HDPE Ø=36" | 3d | 2025-01-17 | 2025-01-20 | A1160 SS | 23d |
| A1180 |  | SUMINISTRO Y MONTAJE DE PANELES DE C°A° 1.9mx1.0mx0.20m EN PASE DE AGUA | 2d | 2025-01-20 | 2025-01-21 | A1170 SS+2d | 23d |
| A1190 |  | SUMINISTRO Y MONTAJE DE PANELES DE C°A° 1.6mx1.0mx0.20m EN PASE DE AGUA | 2d | 2025-01-20 | 2025-01-21 | A1180 SS | 24d |
| A4660 |  | SUMINISTRO Y MONTAJE DE PANELES DE C°A° 1.8mx1.0mx0.20m EN PASE DE AGUA | 2d | 2025-01-21 | 2025-01-22 | A1180 SS+1d | 23d |
|  | 4 | **CABEZAL DE ENTRADA Y SALIDA** |  | 2025-01-23 | 2025-02-03 |  |  |
| A1210 |  | ENCOFRADO Y DESENCOFRADO NORMAL | 6d | 2025-01-23 | 2025-01-29 | A1190, A4660 | 23d |
| A1200 |  | CONCRETO 175 Kg/Cm2 | 4d | 2025-01-30 | 2025-02-03 | A1210 | 23d |
|  | 4 | **DESCOLMATACIÓN DE CAUCE Y OBRAS AUXILIARES** |  | 2023-12-05 | 2025-03-01 |  |  |
|  | 1 | **DESBROCE Y DESCOLMATACIÓN** |  | 2023-12-05 | 2025-03-01 |  |  |
| A1220 |  | DESBROCE Y LIMPIEZA EN ZONA NO BOSCOSA | 300d | 2023-12-05 | 2024-11-18 | A1060 SS+3d | 0d |
| A1230 |  | DESCOLMATACIÓN DE CAUCE NATURAL DEL RÍO LACRAMARCA | 279d | 2023-12-07 | 2024-10-26 | A1220 SS+2d | 0d |
| A1880 |  | CONFORMACIÓN DE DESVIO EN CAUCE DE RÍO | 384d | 2023-12-11 | 2025-03-01 | A1230 SS+3d | 0d |
| A1870 |  | RELLENO NO ESTRUCTURAL CON MATERIAL PROPIO | 382d | 2023-12-13 | 2025-03-01 | A1880 SS+2d | 0d |
|  | 7 | **CRUCE VEHICULAR** |  | 2025-01-10 | 2025-02-12 |  |  |
|  | 1 | **MEJORAMIENTO DE CRUCE VEHICULAR** |  | 2025-01-10 | 2025-02-12 |  |  |
| A4670 |  | VACIADO DE CONCRETO f´c=280 Kg/cm2 | 3d | 2025-01-10 | 2025-01-13 | A8390 SS | 15d |
| A4680 |  | VACIADO DE CONCRETO CICLÓPEO f'c=170 kg/cm2 | 3d | 2025-01-14 | 2025-01-16 | A4670 | 15d |
| A4690 |  | ACERO DE REFUERZO fy=4200 kg/cm2 | 21d | 2025-01-17 | 2025-02-10 | A4680 | 15d |
| A4700 |  | ENCOFRADO Y DESENCOFRADO NORMAL | 15d | 2025-01-24 | 2025-02-10 | A4690 SS+6d | 15d |
| A4710 |  | MONTAJE DE LOSA PREFABRICADA | 11d | 2025-01-31 | 2025-02-12 | A4700 SS+6d | 15d |
|  | 6 | **RAMPAS** |  | 2024-02-29 | 2025-02-28 |  |  |
|  | 1 | **CONSTRUCCION DE RAMPAS** |  | 2024-02-29 | 2025-02-28 |  |  |
| A1710 |  | EXCAVACIÓN EN TERRENO NATURAL CON EQUIPO | 314d | 2024-02-29 | 2025-02-28 | A7470 FS+2d | 1d |
| A1720 |  | CONFORMACIÓN DE CUERPO DE RAMPA CON MATERIAL PROPIO | 313d | 2024-03-01 | 2025-02-28 | A1710 SS+1d | 1d |
| A1730 |  | CONFORMACIÓN DE CORONACIÓN DE RAMPA | 312d | 2024-03-02 | 2025-02-28 | A1720 SS+1d | 1d |
|  | 16 | **DIQUES DE TIERRA COMPACTADA CON ENROCADO** |  | 2023-12-06 | 2025-03-01 |  |  |
|  | 16 | **DIQUE A2-I-03** |  | 2023-12-06 | 2025-03-01 |  |  |
|  | 2 | **DIQUE DE TIERRA COMPACTADA A2-I-03 SIN AFECTACION** |  | 2023-12-06 | 2024-02-28 |  |  |
| A7420 |  | ENTREGA DE TERRENO | 0d | 2023-12-06 | 2023-12-06 | A1040 | 0d |
| A7430 |  | EXCAVACIÓN EN TERRENO NATURAL CON EQUIPO | 52d | 2023-12-07 | 2024-02-05 | A7420 SS+1d | 0d |
| A7440 |  | EXCAVACIÓN DE UÑA CON EQUIPO | 52d | 2023-12-08 | 2024-02-06 | A7430 SS+1d | 0d |
| A7450 |  | PERFILADO EN ZONA DE CORTE TALUD DE DIQUE | 52d | 2023-12-08 | 2024-02-06 | A7430 SS+1d | 0d |
| A7460 |  | PREPARACIÓN DE FUNDACIÓN DE CUERPO DE DIQUE | 52d | 2023-12-09 | 2024-02-07 | A7430 SS+1d, A7450 SS+1d, A7440 SS+1d | 0d |
| A7470 |  | CONFORMACIÓN DE CUERPO DE DIQUE CON MATERIAL PROPIO | 52d | 2023-12-28 | 2024-02-26 | A7460 SS+16d | 0d |
| A7480 |  | GEOTEXTIL NO TEJIDO 400 G/M2, INC. COLOCACIÓN | 52d | 2023-12-28 | 2024-02-26 | A7470 SS | 0d |
| A7490 |  | PERFILADO Y COMPACTACIÓN EN ZONA DE CORTE EN CORONA | 52d | 2023-12-28 | 2024-02-26 | A7480 SS | 0d |
| A7500 |  | CONFORMACIÓN DE MATERIAL GRANULAR EN CORONA DE DIQUE | 52d | 2023-12-29 | 2024-02-27 | A7490 SS+1d | 0d |
| A7510 |  | COLOCACION Y ACOMODO DE ROCA EN UÑA DE DIQUE | 52d | 2023-12-29 | 2024-02-27 | A7500 SS | 0d |
| A7520 |  | COLOCACION Y ACOMODO DE ROCA EN TALUD DE DIQUE | 53d | 2023-12-29 | 2024-02-28 | A7510 SS | 28d |
|  | 12 | **DIQUE DE TIERRA COMPACTADA A2-I-03 CON AFECTACION** |  | 2024-10-30 | 2024-11-29 |  |  |
| A7540 |  | ENTREGA DE TERRENO | 0d | 2024-10-30 | 2024-10-30 | A8630 | 79d |
| A7530 |  | EXCAVACIÓN EN TERRENO NATURAL CON EQUIPO | 15d | 2024-10-31 | 2024-11-16 | A7540 SS+1d | 79d |
| A7550 |  | EXCAVACIÓN DE UÑA CON EQUIPO | 15d | 2024-11-01 | 2024-11-18 | A7530 SS+1d | 80d |
| A7560 |  | PERFILADO EN ZONA DE CORTE TALUD DE DIQUE | 15d | 2024-11-02 | 2024-11-19 | A7530 SS+2d | 79d |
| A7570 |  | PREPARACIÓN DE FUNDACIÓN DE CUERPO DE DIQUE | 15d | 2024-11-04 | 2024-11-20 | A7530 SS+1d, A7560 SS+1d, A7550 SS+1d | 79d |
| A7580 |  | CONFORMACIÓN DE CUERPO DE DIQUE CON MATERIAL PROPIO | 15d | 2024-11-05 | 2024-11-21 | A7570 SS+1d | 79d |
| A7590 |  | GEOTEXTIL NO TEJIDO 400 G/M2, INC. COLOCACIÓN | 15d | 2024-11-06 | 2024-11-22 | A7580 SS+1d | 79d |

| ID | WBS | Task | Duration | Start | Finish | Predecessors | Total float |
| --- | --- | --- | --- | --- | --- | --- | --- |
| A7600 |  | PERFILADO Y COMPACTACIÓN EN ZONA DE CORTE EN CORONA | 15d | 2024-11-07 | 2024-11-23 | A7590 SS+1d | 79d |
| A7610 |  | CONFORMACIÓN DE MATERIAL GRANULAR EN CORONA DE DIQUE | 15d | 2024-11-08 | 2024-11-25 | A7600 SS+1d | 79d |
| A7620 |  | COLOCACION Y ACOMODO DE ROCA EN UÑA DE DIQUE | 15d | 2024-11-11 | 2024-11-27 | A7610 SS+2d | 79d |
| A7630 |  | COLOCACION Y ACOMODO DE ROCA EN TALUD DE DIQUE | 15d | 2024-11-13 | 2024-11-29 | A7620 SS+2d | 79d |
|  | 14 | **DIQUE DE TIERRA COMPACTADA A2-I-03 POR LIBERAR** |  | 2025-01-10 | 2025-03-01 |  |  |
| A7640 |  | ENTREGA DE TERRENO | 0d | 2025-01-10 | 2025-01-10 | A9300 | 0d |
| A7650 |  | EXCAVACIÓN EN TERRENO NATURAL CON EQUIPO | 33d | 2025-01-11 | 2025-02-18 | A7640 SS+1d | 0d |
| A7660 |  | EXCAVACIÓN DE UÑA CON EQUIPO | 33d | 2025-01-14 | 2025-02-20 | A7650 SS+2d | 0d |
| A7670 |  | PERFILADO EN ZONA DE CORTE TALUD DE DIQUE | 33d | 2025-01-14 | 2025-02-20 | A7650 SS+2d | 0d |
| A7680 |  | PREPARACIÓN DE FUNDACIÓN DE CUERPO DE DIQUE | 33d | 2025-01-15 | 2025-02-21 | A7650 SS+1d, A7670 SS+1d, A7660 SS+1d | 0d |
| A7690 |  | CONFORMACIÓN DE CUERPO DE DIQUE CON MATERIAL PROPIO | 33d | 2025-01-16 | 2025-02-22 | A7680 SS+1d | 0d |
| A7700 |  | GEOTEXTIL NO TEJIDO 400 G/M2, INC. COLOCACIÓN | 33d | 2025-01-18 | 2025-02-25 | A7690 SS+2d | 0d |
| A7710 |  | PERFILADO Y COMPACTACIÓN EN ZONA DE CORTE EN CORONA | 33d | 2025-01-18 | 2025-02-25 | A7700 SS | 0d |
| A7720 |  | CONFORMACIÓN DE MATERIAL GRANULAR EN CORONA DE DIQUE | 33d | 2025-01-20 | 2025-02-26 | A7710 SS+1d | 0d |
| A7730 |  | COLOCACION Y ACOMODO DE ROCA EN UÑA DE DIQUE | 33d | 2025-01-22 | 2025-02-28 | A7720 SS+2d | 0d |
| A7740 |  | COLOCACION Y ACOMODO DE ROCA EN TALUD DE DIQUE | 33d | 2025-01-23 | 2025-03-01 | A7730 SS+1d | 0d |
|  | 8 | **DIQUE A2-I-2** |  | 2024-01-31 | 2024-10-28 |  |  |
|  | 6 | **DIQUE DE TIERRA COMPACTADA A2-I-02 SIN AFECTACION** |  | 2024-01-31 | 2024-05-04 |  |  |
| A7750 |  | ENTREGA DE TERRENO | 0d | 2024-01-31 | 2024-01-31 | A8270, A7520 SS | 0d |
| A7760 |  | EXCAVACIÓN EN TERRENO NATURAL CON EQUIPO | 72d | 2024-02-01 | 2024-04-24 | A7750 SS+1d | 0d |
| A7770 |  | EXCAVACIÓN DE UÑA CON EQUIPO | 72d | 2024-02-02 | 2024-04-25 | A7760 SS+1d | 0d |
| A7780 |  | PERFILADO EN ZONA DE CORTE TALUD DE DIQUE | 72d | 2024-02-02 | 2024-04-25 | A7760 SS+1d | 1d |
| A7790 |  | PREPARACIÓN DE FUNDACIÓN DE CUERPO DE DIQUE | 72d | 2024-02-03 | 2024-04-26 | A7760 SS+1d, A7780 SS, A7770 SS+1d | 0d |
| A7800 |  | PEDRAPLEN e=60 cm | 72d | 2024-02-03 | 2024-04-26 | A7780 FF+1d | 1d |
| A7810 |  | PEDRAPLEN e=30 cm | 72d | 2024-02-03 | 2024-04-26 | A7800 FF | 1d |
| A7820 |  | CONFORMACIÓN DE CUERPO DE DIQUE CON MATERIAL PROPIO | 72d | 2024-02-05 | 2024-04-27 | A7790 SS+1d, A7810 SS | 0d |
| A7830 |  | CONFORMACIÓN DE RELLENO NO ESTRUCTURAL CON MATERIAL PROPIO | 72d | 2024-02-06 | 2024-04-29 | A7820 SS+1d | 0d |
| A7840 |  | GEOTEXTIL NO TEJIDO 400 G/M2, INC. COLOCACIÓN | 72d | 2024-02-07 | 2024-04-30 | A7820 SS, A7830 SS+1d | 0d |
| A7850 |  | PERFILADO Y COMPACTACIÓN EN ZONA DE CORTE EN CORONA | 72d | 2024-02-08 | 2024-05-01 | A7840 SS+1d | 0d |
| A7860 |  | CONFORMACIÓN DE MATERIAL GRANULAR EN CORONA DE DIQUE | 72d | 2024-02-09 | 2024-05-02 | A7850 SS+1d | 0d |
| A7870 |  | COLOCACION Y ACOMODO DE ROCA EN UÑA DE DIQUE | 72d | 2024-02-10 | 2024-05-03 | A7860 SS+1d | 0d |
| A7880 |  | COLOCACION Y ACOMODO DE ROCA EN TALUD DE DIQUE | 72d | 2024-02-12 | 2024-05-04 | A7870 SS+1d | 0d |
|  | 7 | **DIQUE DE TIERRA COMPACTADA A2-I-02 CON AFECTACION** |  | 2024-08-31 | 2024-10-12 |  |  |
| A7890 |  | ENTREGA DE TERRENO | 0d | 2024-08-31 | 2024-08-31 | A9020 | 107d |
| A7900 |  | EXCAVACIÓN EN TERRENO NATURAL CON EQUIPO | 25d | 2024-09-02 | 2024-09-30 | A7890 SS+1d | 107d |
| A7910 |  | EXCAVACIÓN DE UÑA CON EQUIPO | 25d | 2024-09-03 | 2024-10-01 | A7900 SS+1d | 108d |
| A7920 |  | PERFILADO EN ZONA DE CORTE TALUD DE DIQUE | 25d | 2024-09-04 | 2024-10-02 | A7900 SS+2d | 107d |
| A7930 |  | PREPARACIÓN DE FUNDACIÓN DE CUERPO DE DIQUE | 25d | 2024-09-04 | 2024-10-02 | A7900 SS+1d, A7920 SS, A7910 SS+1d | 108d |
| A7940 |  | PEDRAPLEN e=60 cm | 25d | 2024-09-05 | 2024-10-03 | A7920 FF+1d | 107d |
| A7950 |  | CONFORMACIÓN DE CUERPO DE DIQUE CON MATERIAL PROPIO | 25d | 2024-09-06 | 2024-10-04 | A7930 SS+1d, A7960 SS | 107d |
| A7960 |  | PEDRAPLEN e=30 cm | 25d | 2024-09-06 | 2024-10-04 | A7940 FF+1d | 107d |
| A7970 |  | CONFORMACIÓN DE RELLENO NO ESTRUCTURAL CON MATERIAL PROPIO | 25d | 2024-09-07 | 2024-10-05 | A7950 SS+1d | 107d |
| A7980 |  | GEOTEXTIL NO TEJIDO 400 G/M2, INC. COLOCACIÓN | 25d | 2024-09-09 | 2024-10-07 | A7950 SS, A7970 SS+1d | 107d |
| A7990 |  | PERFILADO Y COMPACTACIÓN EN ZONA DE CORTE EN CORONA | 25d | 2024-09-11 | 2024-10-09 | A7980 SS+2d | 107d |
| A8000 |  | CONFORMACIÓN DE MATERIAL GRANULAR EN CORONA DE DIQUE | 25d | 2024-09-12 | 2024-10-10 | A7990 SS+1d | 107d |
| A8010 |  | COLOCACION Y ACOMODO DE ROCA EN UÑA DE DIQUE | 25d | 2024-09-13 | 2024-10-11 | A8000 SS+1d | 107d |
| A8020 |  | COLOCACION Y ACOMODO DE ROCA EN TALUD DE DIQUE | 25d | 2024-09-14 | 2024-10-12 | A8010 SS+1d | 107d |
|  | 11 | **DIQUE DE TIERRA COMPACTADA A2-I-02 POR LIBERAR** |  | 2024-10-14 | 2024-10-28 |  |  |
| A8030 |  | ENTREGA DE TERRENO | 0d | 2024-10-14 | 2024-10-14 | A8020 | 107d |
| A8040 |  | EXCAVACIÓN EN TERRENO NATURAL CON EQUIPO | 5d | 2024-10-15 | 2024-10-19 | A8030 SS+1d | 107d |
| A8050 |  | EXCAVACIÓN DE UÑA CON EQUIPO | 5d | 2024-10-16 | 2024-10-21 | A8040 SS+1d | 107d |
| A8060 |  | PERFILADO EN ZONA DE CORTE TALUD DE DIQUE | 5d | 2024-10-16 | 2024-10-21 | A8040 SS+1d | 108d |
| A8070 |  | PREPARACIÓN DE FUNDACIÓN DE CUERPO DE DIQUE | 5d | 2024-10-17 | 2024-10-22 | A8040 SS+1d, A8060 SS, A8050 SS+1d | 107d |
| A8080 |  | PEDRAPLEN e=60 cm | 5d | 2024-10-17 | 2024-10-22 | A8060 FF+1d | 108d |
| A8090 |  | PEDRAPLEN e=30 cm | 5d | 2024-10-17 | 2024-10-22 | A8080 FF | 108d |
| A8100 |  | CONFORMACIÓN DE CUERPO DE DIQUE CON MATERIAL PROPIO | 5d | 2024-10-18 | 2024-10-23 | A8070 SS+1d, A8090 SS | 107d |
| A8110 |  | CONFORMACIÓN DE RELLENO NO ESTRUCTURAL CON MATERIAL PROPIO | 5d | 2024-10-19 | 2024-10-24 | A8100 SS+1d | 107d |
| A8120 |  | GEOTEXTIL NO TEJIDO 400 G/M2, INC. COLOCACIÓN | 5d | 2024-10-21 | 2024-10-25 | A8100 SS, A8110 SS+1d | 107d |
| A8130 |  | PERFILADO Y COMPACTACIÓN EN ZONA DE CORTE EN CORONA | 5d | 2024-10-22 | 2024-10-26 | A8120 SS+1d | 107d |
| A8140 |  | CONFORMACIÓN DE MATERIAL GRANULAR EN CORONA DE DIQUE | 4d | 2024-10-23 | 2024-10-26 | A8130 SS+1d | 107d |
| A8150 |  | COLOCACION Y ACOMODO DE ROCA EN UÑA DE DIQUE | 4d | 2024-10-24 | 2024-10-28 | A8140 SS+1d | 107d |
| A8160 |  | COLOCACION Y ACOMODO DE ROCA EN TALUD DE DIQUE | 4d | 2024-10-24 | 2024-10-28 | A8150 SS | 107d |
|  | 10 | **DIQUE A2-I-1** |  | 2024-08-31 | 2025-02-07 |  |  |
|  | 9 | **DIQUE DE TIERRA COMPACTADA A2-I-01 SIN AFECTACION** |  | 2024-08-31 | 2024-10-29 |  |  |
| A8500 |  | ENTREGA DE TERRENO | 0d | 2024-08-31 | 2024-08-31 | A9020 | 79d |
| A8510 |  | EXCAVACIÓN EN TERRENO NATURAL CON EQUIPO | 41d | 2024-09-02 | 2024-10-18 | A8500 SS+1d | 79d |
| A8520 |  | EXCAVACIÓN DE UÑA CON EQUIPO | 41d | 2024-09-03 | 2024-10-19 | A8510 SS+1d | 79d |
| A8530 |  | PERFILADO EN ZONA DE CORTE TALUD DE DIQUE | 41d | 2024-09-03 | 2024-10-19 | A8510 SS+1d | 80d |
| A8540 |  | PREPARACIÓN DE FUNDACIÓN DE CUERPO DE DIQUE | 41d | 2024-09-04 | 2024-10-21 | A8510 SS+1d, A8530 SS, A8520 SS+1d | 79d |
| A8550 |  | PEDRAPLEN e=60 cm | 41d | 2024-09-04 | 2024-10-21 | A8530 FF+1d | 80d |

| ID | WBS | Task | Duration | Start | Finish | Predecessors | Total float |
| --- | --- | --- | --- | --- | --- | --- | --- |
| A8560 |  | PEDRAPLEN e=30 cm | 41d | 2024-09-04 | 2024-10-21 | A8550 FF | 80d |
| A8570 |  | CONFORMACIÓN DE CUERPO DE DIQUE CON MATERIAL PROPIO | 41d | 2024-09-05 | 2024-10-22 | A8540 SS+1d, A8560 SS | 79d |
| A8580 |  | CONFORMACIÓN DE RELLENO NO ESTRUCTURAL CON MATERIAL PROPIO | 41d | 2024-09-06 | 2024-10-23 | A8570 SS+1d | 79d |
| A8590 |  | GEOTEXTIL NO TEJIDO 400 G/M2, INC. COLOCACIÓN | 41d | 2024-09-07 | 2024-10-24 | A8570 SS, A8580 SS+1d | 79d |
| A8600 |  | PERFILADO Y COMPACTACIÓN EN ZONA DE CORTE EN CORONA | 41d | 2024-09-09 | 2024-10-25 | A8590 SS+1d | 79d |
| A8610 |  | CONFORMACIÓN DE MATERIAL GRANULAR EN CORONA DE DIQUE | 41d | 2024-09-10 | 2024-10-26 | A8600 SS+1d | 79d |
| A8620 |  | COLOCACION Y ACOMODO DE ROCA EN UÑA DE DIQUE | 41d | 2024-09-11 | 2024-10-28 | A8610 SS+1d | 79d |
| A8630 |  | COLOCACION Y ACOMODO DE ROCA EN TALUD DE DIQUE | 41d | 2024-09-12 | 2024-10-29 | A8620 SS+1d | 79d |
|  | 8 | **DIQUE DE TIERRA COMPACTADA A2-I-01B SIN AFECTACION** |  | 2024-08-31 | 2024-09-12 |  |  |
| A8640 |  | ENTREGA DE TERRENO | 0d | 2024-08-31 | 2024-08-31 | A9020 | 0d |
| A8650 |  | EXCAVACIÓN EN TERRENO NATURAL CON EQUIPO | 6d | 2024-09-02 | 2024-09-07 | A8640 SS+1d | 0d |
| A8660 |  | EXCAVACIÓN DE UÑA CON EQUIPO | 6d | 2024-09-03 | 2024-09-09 | A8650 SS+1d | 0d |
| A8670 |  | PERFILADO EN ZONA DE CORTE TALUD DE DIQUE | 6d | 2024-09-03 | 2024-09-09 | A8650 SS+1d | 0d |
| A8680 |  | PREPARACIÓN DE FUNDACIÓN DE CUERPO DE DIQUE | 6d | 2024-09-04 | 2024-09-10 | A8650 SS+1d, A8670 SS+1d, A8660 SS+1d | 0d |
| A8690 |  | CONFORMACIÓN DE CUERPO DE DIQUE CON MATERIAL PROPIO | 6d | 2024-09-05 | 2024-09-11 | A8680 SS+1d | 0d |
| A8700 |  | GEOTEXTIL NO TEJIDO 400 G/M2, INC. COLOCACIÓN | 6d | 2024-09-05 | 2024-09-11 | A8690 SS | 0d |
| A8710 |  | PERFILADO Y COMPACTACIÓN EN ZONA DE CORTE EN CORONA | 6d | 2024-09-05 | 2024-09-11 | A8700 SS | 0d |
| A8720 |  | CONFORMACIÓN DE MATERIAL GRANULAR EN CORONA DE DIQUE | 6d | 2024-09-06 | 2024-09-12 | A8710 SS+1d | 0d |
| A8730 |  | COLOCACION Y ACOMODO DE ROCA EN UÑA DE DIQUE | 6d | 2024-09-06 | 2024-09-12 | A8720 SS | 0d |
| A8740 |  | COLOCACION Y ACOMODO DE ROCA EN TALUD DE DIQUE | 6d | 2024-09-06 | 2024-09-12 | A8730 SS | 0d |
|  | 15 | **DIQUE DE TIERRA COMPACTADA A2-I-01 POR LIBERAR** |  | 2025-01-10 | 2025-02-07 |  |  |
| A8750 |  | ENTREGA DE TERRENO | 0d | 2025-01-10 | 2025-01-10 | A9300 | 19d |
| A8760 |  | EXCAVACIÓN EN TERRENO NATURAL CON EQUIPO | 13d | 2025-01-11 | 2025-01-25 | A8750 SS+1d | 19d |
| A8770 |  | EXCAVACIÓN DE UÑA CON EQUIPO | 13d | 2025-01-13 | 2025-01-27 | A8760 SS+1d | 19d |
| A8780 |  | PERFILADO EN ZONA DE CORTE TALUD DE DIQUE | 13d | 2025-01-13 | 2025-01-27 | A8760 SS+1d | 20d |
| A8790 |  | PREPARACIÓN DE FUNDACIÓN DE CUERPO DE DIQUE | 13d | 2025-01-14 | 2025-01-28 | A8760 SS+2d, A8780 SS, A8770 SS+1d | 19d |
| A8800 |  | PEDRAPLEN e=60 cm | 13d | 2025-01-15 | 2025-01-29 | A8780 FF+2d | 20d |
| A8810 |  | PEDRAPLEN e=30 cm | 13d | 2025-01-15 | 2025-01-29 | A8800 FF | 20d |
| A8820 |  | CONFORMACIÓN DE CUERPO DE DIQUE CON MATERIAL PROPIO | 13d | 2025-01-16 | 2025-01-30 | A8790 SS+2d, A8810 SS | 19d |
| A8830 |  | CONFORMACIÓN DE RELLENO NO ESTRUCTURAL CON MATERIAL PROPIO | 13d | 2025-01-17 | 2025-01-31 | A8820 SS+1d | 19d |
| A8840 |  | GEOTEXTIL NO TEJIDO 400 G/M2, INC. COLOCACIÓN | 13d | 2025-01-18 | 2025-02-01 | A8820 SS, A8830 SS+1d | 19d |
| A8850 |  | PERFILADO Y COMPACTACIÓN EN ZONA DE CORTE EN CORONA | 13d | 2025-01-20 | 2025-02-03 | A8840 SS+1d | 19d |
| A8860 |  | CONFORMACIÓN DE MATERIAL GRANULAR EN CORONA DE DIQUE | 13d | 2025-01-21 | 2025-02-04 | A8850 SS+1d | 19d |
| A8870 |  | COLOCACION Y ACOMODO DE ROCA EN UÑA DE DIQUE | 13d | 2025-01-23 | 2025-02-06 | A8860 SS+2d | 19d |
| A8880 |  | COLOCACION Y ACOMODO DE ROCA EN TALUD DE DIQUE | 13d | 2025-01-24 | 2025-02-07 | A8870 SS+1d | 19d |
|  | 9 | **DIQUE A2-D-2** |  | 2023-12-06 | 2025-02-18 |  |  |
|  | 1 | **DIQUE DE TIERRA COMPACTADA A2-D-02 SIN AFECTACIÓN** |  | 2023-12-06 | 2024-01-30 |  |  |
| A8170 |  | ENTREGA DE TERRENO | 0d | 2023-12-06 | 2023-12-06 | A1040 | 0d |
| A8180 |  | EXCAVACIÓN EN TERRENO NATURAL CON EQUIPO | 25d | 2023-12-07 | 2024-01-04 | A8170 SS+1d | 0d |
| A8190 |  | EXCAVACIÓN DE UÑA CON EQUIPO | 25d | 2023-12-08 | 2024-01-05 | A8180 SS+1d | 0d |
| A8200 |  | PERFILADO EN ZONA DE CORTE TALUD DE DIQUE | 25d | 2023-12-08 | 2024-01-05 | A8180 SS+1d | 0d |
| A8210 |  | PREPARACIÓN DE FUNDACIÓN DE CUERPO DE DIQUE | 25d | 2023-12-09 | 2024-01-06 | A8180 SS+1d, A8200 SS+1d, A8190 SS+1d | 0d |
| A8220 |  | CONFORMACIÓN DE CUERPO DE DIQUE CON MATERIAL PROPIO | 25d | 2023-12-28 | 2024-01-25 | A8210 SS+16d | 0d |
| A8230 |  | GEOTEXTIL NO TEJIDO 400 G/M2, INC. COLOCACIÓN | 25d | 2023-12-28 | 2024-01-25 | A8220 SS | 0d |
| A8240 |  | PERFILADO Y COMPACTACIÓN EN ZONA DE CORTE EN CORONA | 25d | 2023-12-29 | 2024-01-26 | A8230 SS+1d | 0d |
| A8250 |  | CONFORMACIÓN DE MATERIAL GRANULAR EN CORONA DE DIQUE | 25d | 2023-12-30 | 2024-01-27 | A8240 SS+1d | 0d |
| A8260 |  | COLOCACION Y ACOMODO DE ROCA EN UÑA DE DIQUE | 25d | 2024-01-01 | 2024-01-29 | A8250 SS+1d | 0d |
| A8270 |  | COLOCACION Y ACOMODO DE ROCA EN TALUD DE DIQUE | 25d | 2024-01-02 | 2024-01-30 | A8260 SS+1d | 0d |
|  | 3 | **DIQUE DE TIERRA COMPACTADA A2-D-02 CON AFECTACION** |  | 2024-09-13 | 2024-10-07 |  |  |
| A8280 |  | ENTREGA DE TERRENO | 0d | 2024-09-13 | 2024-09-13 | A8740 | 0d |
| A8290 |  | EXCAVACIÓN EN TERRENO NATURAL CON EQUIPO | 16d | 2024-09-14 | 2024-10-02 | A8280 SS+1d | 0d |
| A8300 |  | EXCAVACIÓN DE UÑA CON EQUIPO | 16d | 2024-09-16 | 2024-10-03 | A8290 SS+1d | 0d |
| A8310 |  | PERFILADO EN ZONA DE CORTE TALUD DE DIQUE | 16d | 2024-09-16 | 2024-10-03 | A8290 SS+1d | 0d |
| A8320 |  | PREPARACIÓN DE FUNDACIÓN DE CUERPO DE DIQUE | 16d | 2024-09-17 | 2024-10-04 | A8290 SS+1d, A8310 SS+1d, A8300 SS+1d | 0d |
| A8330 |  | CONFORMACIÓN DE CUERPO DE DIQUE CON MATERIAL PROPIO | 16d | 2024-09-18 | 2024-10-05 | A8320 SS+1d | 0d |
| A8340 |  | GEOTEXTIL NO TEJIDO 400 G/M2, INC. COLOCACIÓN | 16d | 2024-09-18 | 2024-10-05 | A8330 SS | 0d |
| A8350 |  | PERFILADO Y COMPACTACIÓN EN ZONA DE CORTE EN CORONA | 16d | 2024-09-18 | 2024-10-05 | A8340 SS | 0d |
| A8360 |  | CONFORMACIÓN DE MATERIAL GRANULAR EN CORONA DE DIQUE | 16d | 2024-09-19 | 2024-10-07 | A8350 SS+1d | 0d |
| A8370 |  | COLOCACION Y ACOMODO DE ROCA EN UÑA DE DIQUE | 16d | 2024-09-19 | 2024-10-07 | A8360 SS | 0d |
| A8380 |  | COLOCACION Y ACOMODO DE ROCA EN TALUD DE DIQUE | 16d | 2024-09-19 | 2024-10-07 | A8370 SS | 0d |
|  | 13 | **DIQUE DE TIERRA COMPACTADA A2-D-02 POR LIBERAR** |  | 2025-01-10 | 2025-02-18 |  |  |
| A8390 |  | ENTREGA DE TERRENO | 0d | 2025-01-10 | 2025-01-10 | A9300 | 10d |
| A8400 |  | EXCAVACIÓN EN TERRENO NATURAL CON EQUIPO | 18d | 2025-01-11 | 2025-01-31 | A8390 SS+1d | 10d |
| A8410 |  | EXCAVACIÓN DE UÑA CON EQUIPO | 18d | 2025-01-13 | 2025-02-01 | A8400 SS+1d | 11d |
| A8420 |  | PERFILADO EN ZONA DE CORTE TALUD DE DIQUE | 18d | 2025-01-14 | 2025-02-03 | A8400 SS+2d | 10d |
| A8430 |  | PREPARACIÓN DE FUNDACIÓN DE CUERPO DE DIQUE | 18d | 2025-01-15 | 2025-02-04 | A8400 SS+1d, A8420 SS+1d, A8410 SS+1d | 10d |
| A8440 |  | CONFORMACIÓN DE CUERPO DE DIQUE CON MATERIAL PROPIO | 18d | 2025-01-17 | 2025-02-06 | A8430 SS+2d | 10d |
| A8450 |  | GEOTEXTIL NO TEJIDO 400 G/M2, INC. COLOCACIÓN | 18d | 2025-01-20 | 2025-02-08 | A8440 SS+2d | 10d |
| A8460 |  | PERFILADO Y COMPACTACIÓN EN ZONA DE CORTE EN CORONA | 18d | 2025-01-22 | 2025-02-11 | A8450 SS+2d | 10d |
| A8470 |  | CONFORMACIÓN DE MATERIAL GRANULAR EN CORONA DE DIQUE | 18d | 2025-01-24 | 2025-02-13 | A8460 SS+2d | 10d |

| ID | WBS | Task | Duration | Start | Finish | Predecessors | Total float |
| --- | --- | --- | --- | --- | --- | --- | --- |
| A8480 |  | COLOCACION Y ACOMODO DE ROCA EN UÑA DE DIQUE | 18d | 2025-01-27 | 2025-02-15 | A8470 SS+2d | 10d |
| A8490 |  | COLOCACION Y ACOMODO DE ROCA EN TALUD DE DIQUE | 18d | 2025-01-29 | 2025-02-18 | A8480 SS+2d | 10d |
|  | 11 | **DIQUE A2-D-1** |  | 2024-05-06 | 2025-01-09 |  |  |
|  | 10 | **DIQUE DE TIERRA COMPACTADA A2-D-01 SIN AFECTACION** |  | 2024-05-06 | 2024-08-30 |  |  |
| A8890 |  | ENTREGA DE TERRENO | 0d | 2024-05-06 | 2024-05-06 | A7880 | 0d |
| A8900 |  | EXCAVACIÓN EN TERRENO NATURAL CON EQUIPO | 91d | 2024-05-07 | 2024-08-20 | A8890 SS+1d | 0d |
| A8910 |  | PERFILADO EN ZONA DE CORTE TALUD DE DIQUE | 91d | 2024-05-07 | 2024-08-20 | A8900 SS | 1d |
| A8920 |  | EXCAVACIÓN DE UÑA CON EQUIPO | 91d | 2024-05-08 | 2024-08-21 | A8900 SS+1d | 0d |
| A8930 |  | PREPARACIÓN DE FUNDACIÓN DE CUERPO DE DIQUE | 91d | 2024-05-09 | 2024-08-22 | A8900 SS+1d, A8910 SS, A8920 SS+1d | 0d |
| A8940 |  | PEDRAPLEN e=60 cm | 91d | 2024-05-09 | 2024-08-22 | A8910 FF+2d | 1d |
| A8950 |  | PEDRAPLEN e=30 cm | 91d | 2024-05-09 | 2024-08-22 | A8940 FF | 1d |
| A8960 |  | CONFORMACIÓN DE CUERPO DE DIQUE CON MATERIAL PROPIO | 91d | 2024-05-10 | 2024-08-23 | A8930 SS+1d, A8950 SS | 0d |
| A8970 |  | CONFORMACIÓN DE RELLENO NO ESTRUCTURAL CON MATERIAL PROPIO | 91d | 2024-05-11 | 2024-08-24 | A8960 SS+1d | 0d |
| A8980 |  | GEOTEXTIL NO TEJIDO 400 G/M2, INC. COLOCACIÓN | 91d | 2024-05-13 | 2024-08-26 | A8960 SS, A8970 SS+1d | 0d |
| A8990 |  | PERFILADO Y COMPACTACIÓN EN ZONA DE CORTE EN CORONA | 91d | 2024-05-14 | 2024-08-27 | A8980 SS+1d | 0d |
| A9000 |  | CONFORMACIÓN DE MATERIAL GRANULAR EN CORONA DE DIQUE | 91d | 2024-05-15 | 2024-08-28 | A8990 SS+1d | 0d |
| A9010 |  | COLOCACION Y ACOMODO DE ROCA EN UÑA DE DIQUE | 91d | 2024-05-16 | 2024-08-29 | A9000 SS+1d | 0d |
| A9020 |  | COLOCACION Y ACOMODO DE ROCA EN TALUD DE DIQUE | 91d | 2024-05-17 | 2024-08-30 | A9010 SS+1d | 0d |
|  | 4 | **DIQUE DE TIERRA COMPACTADA A2-D-01 CON AFECTACION** |  | 2024-10-08 | 2024-11-14 |  |  |
| A9030 |  | ENTREGA DE TERRENO | 0d | 2024-10-08 | 2024-10-08 | A8380 | 0d |
| A9040 |  | EXCAVACIÓN EN TERRENO NATURAL CON EQUIPO | 18d | 2024-10-09 | 2024-10-29 | A9030 SS+1d | 0d |
| A9050 |  | EXCAVACIÓN DE UÑA CON EQUIPO | 18d | 2024-10-10 | 2024-10-30 | A9040 SS+1d | 3d |
| A9060 |  | PERFILADO EN ZONA DE CORTE TALUD DE DIQUE | 18d | 2024-10-11 | 2024-10-31 | A9040 SS+2d | 0d |
| A9070 |  | PREPARACIÓN DE FUNDACIÓN DE CUERPO DE DIQUE | 18d | 2024-10-11 | 2024-10-31 | A9040 SS+2d, A9060 SS, A9050 SS+1d | 3d |
| A9090 |  | PEDRAPLEN e=60 cm | 18d | 2024-10-14 | 2024-11-02 | A9060 FF+2d | 0d |
| A9080 |  | CONFORMACIÓN DE CUERPO DE DIQUE CON MATERIAL PROPIO | 18d | 2024-10-16 | 2024-11-05 | A9070 SS+1d, A9100 SS | 0d |
| A9100 |  | PEDRAPLEN e=30 cm | 18d | 2024-10-16 | 2024-11-05 | A9090 FF+2d | 0d |
| A9110 |  | CONFORMACIÓN DE RELLENO NO ESTRUCTURAL CON MATERIAL PROPIO | 18d | 2024-10-18 | 2024-11-07 | A9080 SS+2d | 0d |
| A9120 |  | GEOTEXTIL NO TEJIDO 400 G/M2, INC. COLOCACIÓN | 18d | 2024-10-21 | 2024-11-09 | A9080 SS, A9110 SS+2d | 0d |
| A9130 |  | PERFILADO Y COMPACTACIÓN EN ZONA DE CORTE EN CORONA | 18d | 2024-10-22 | 2024-11-11 | A9120 SS+1d | 0d |
| A9140 |  | CONFORMACIÓN DE MATERIAL GRANULAR EN CORONA DE DIQUE | 18d | 2024-10-23 | 2024-11-12 | A9130 SS+1d | 0d |
| A9150 |  | COLOCACION Y ACOMODO DE ROCA EN UÑA DE DIQUE | 18d | 2024-10-24 | 2024-11-13 | A9140 SS+1d | 0d |
| A9160 |  | COLOCACION Y ACOMODO DE ROCA EN TALUD DE DIQUE | 18d | 2024-10-25 | 2024-11-14 | A9150 SS+1d | 0d |
|  | 5 | **DIQUE DE TIERRA COMPACTADA A2-D-01 POR LIBERAR** |  | 2024-11-15 | 2025-01-09 |  |  |
| A9180 |  | ENTREGA DE TERRENO | 0d | 2024-11-15 | 2024-11-15 | A9160 | 0d |
| A9170 |  | EXCAVACIÓN EN TERRENO NATURAL CON EQUIPO | 34d | 2024-11-16 | 2024-12-25 | A9180 SS+1d | 0d |
| A9200 |  | PERFILADO EN ZONA DE CORTE TALUD DE DIQUE | 34d | 2024-11-16 | 2024-12-25 | A9170 SS | 0d |
| A9190 |  | EXCAVACIÓN DE UÑA CON EQUIPO | 34d | 2024-11-18 | 2024-12-26 | A9170 SS+1d | 0d |
| A9220 |  | PEDRAPLEN e=60 cm | 34d | 2024-11-19 | 2024-12-27 | A9200 FF+2d | 0d |
| A9210 |  | PREPARACIÓN DE FUNDACIÓN DE CUERPO DE DIQUE | 34d | 2024-11-20 | 2024-12-28 | A9170 SS+2d, A9200 SS, A9190 SS+2d | 0d |
| A9230 |  | PEDRAPLEN e=30 cm | 34d | 2024-11-21 | 2024-12-30 | A9220 FF+2d | 0d |
| A9240 |  | CONFORMACIÓN DE CUERPO DE DIQUE CON MATERIAL PROPIO | 34d | 2024-11-21 | 2024-12-30 | A9210 SS+1d, A9230 SS | 0d |
| A9250 |  | CONFORMACIÓN DE RELLENO NO ESTRUCTURAL CON MATERIAL PROPIO | 34d | 2024-11-23 | 2025-01-01 | A9240 SS+2d | 0d |
| A9260 |  | GEOTEXTIL NO TEJIDO 400 G/M2, INC. COLOCACIÓN | 34d | 2024-11-25 | 2025-01-02 | A9240 SS, A9250 SS+1d | 0d |
| A9270 |  | PERFILADO Y COMPACTACIÓN EN ZONA DE CORTE EN CORONA | 34d | 2024-11-26 | 2025-01-03 | A9260 SS+1d | 0d |
| A9280 |  | CONFORMACIÓN DE MATERIAL GRANULAR EN CORONA DE DIQUE | 34d | 2024-11-27 | 2025-01-04 | A9270 SS+1d | 0d |
| A9290 |  | COLOCACION Y ACOMODO DE ROCA EN UÑA DE DIQUE | 34d | 2024-11-28 | 2025-01-06 | A9280 SS+1d | 0d |
| A9300 |  | COLOCACION Y ACOMODO DE ROCA EN TALUD DE DIQUE | 36d | 2024-11-29 | 2025-01-09 | A9290 SS+1d | 0d |
|  | 2 | **OBRAS DE ARTE** |  | 2024-02-27 | 2025-03-01 |  |  |
|  | 1 | **CAPTACIÓN** |  | 2024-02-27 | 2025-02-28 |  |  |
| A7240 |  | Construccion de Captaciones | 316d | 2024-02-27 | 2025-02-28 | A7470 | 0d |
|  | 3 | **RETORNO A2-OA-RE-I-11-25** |  | 2024-03-09 | 2025-02-28 |  |  |
| A7250 |  | Construccion de Retorno | 306d | 2024-03-09 | 2025-02-28 | A7240 SS+10d | 0d |
|  | 2 | **RETORNOS Q=100 A 1000 l/s** |  | 2024-03-21 | 2025-02-28 |  |  |
| A7260 |  | Construccion de Retorno | 296d | 2024-03-21 | 2025-02-28 | A7250 SS+10d | 0d |
|  | 4 | **REPOSICIÓN DE CANALES** |  | 2024-04-02 | 2025-03-01 |  |  |
| A7270 |  | Reposicion de Canales | 287d | 2024-04-02 | 2025-03-01 | A7260 SS+10d | 0d |
|  | 5 | **TRANSPORTES** |  | 2023-12-07 | 2025-03-01 |  |  |
|  | 1 | **TRANSPORTES** |  | 2023-12-07 | 2025-03-01 |  |  |
| A7220 |  | TRANSPORTE DE MATERIAL EXCEDENTE PARA DISTANCIAS <1KM | 387d | 2023-12-07 | 2025-03-01 | A7430 SS | 0d |
| A7230 |  | TRANSPORTE DE MATERIAL EXCEDENTE PARA DISTANCIAS >1KM | 387d | 2023-12-07 | 2025-03-01 | A7430 SS | 0d |
| A7170 |  | TRANSPORTE DE MATERIAL GRANULAR PARA DISTANCIAS <1KM | 386d | 2023-12-08 | 2025-03-01 | A7450 SS | 0d |
| A7190 |  | TRANSPORTE DE MATERIAL GRANULAR PARA DISTANCIAS >1KM | 386d | 2023-12-08 | 2025-03-01 | A7450 SS | 0d |
| A7200 |  | TRANSPORTE DE ROCA PARA DISTANCIAS <1KM | 368d | 2023-12-29 | 2025-03-01 | A7510 SS | 0d |
| A7210 |  | TRANSPORTE DE ROCA PARA DISTANCIAS >1KM | 368d | 2023-12-29 | 2025-03-01 | A7510 SS | 0d |
|  | 3 | **ARQUITECTURA Y PAISAJISMO** |  | 2024-11-16 | 2024-12-30 |  |  |
|  | 1 | **OBRAS PRELIMINARES** |  | 2024-11-16 | 2024-11-21 |  |  |
| A3860 |  | Obras Preliminares | 5d | 2024-11-16 | 2024-11-21 | A9170 SS | 53d |
|  | 2 | **MOVIMIENTO DE TIERRAS** |  | 2024-11-16 | 2024-12-26 |  |  |
| A3890 |  | Movimiento de Tierras | 35d | 2024-11-16 | 2024-12-26 | A3860 SS | 53d |

| ID | WBS | Task | Duration | Start | Finish | Predecessors | Total float |
| --- | --- | --- | --- | --- | --- | --- | --- |
|  | 3 | **PAVIMENTOS, RECUBRIMIENTOS Y BORDILLOS** |  | 2024-11-28 | 2024-12-30 |  |  |
| A3930 |  | Pavimientos, Recubrimientos y Bordillos | 28d | 2024-11-28 | 2024-12-30 | A3890 SS+10d | 53d |
|  | 4 | **MOBILIARIOS, BARANDAS Y ESCALERAS** |  | 2024-12-04 | 2024-12-30 |  |  |
| A4000 |  | Instalacion de Moviliarios, Barandas y escaleras | 23d | 2024-12-04 | 2024-12-30 | A3930 SS+5d | 53d |
|  | 4 | **PROGRAMA DE CIERRE DE OBRA** |  | 2023-12-05 | 2025-03-01 |  |  |
| A1770 |  | ACONDICIONAMIENTO DE DEPOSITOS DE MATERIALES EXCEDENTES (DME) | 382d | 2023-12-05 | 2025-02-21 | A1220 SS | 0d |
| A1780 |  | RESTAURACIÓN DE ÁREAS DE INSTALACIONES PROVISIONALES | 7d | 2025-02-22 | 2025-03-01 | A1770 | 0d |

## Version 2 (data date 2023-12-01, saved 2023-10-25, file PER2305-4.xer)

Last finish stays 2025-03-01.

Removed: A1000 KICK OFF MEETING; A1030 CARTEL DE IDENTIFICACIÓN OBRA 4.80 x 3.60 m.

Changed:

| ID | Task | Start | Finish | Duration | Total float | Predecessors | Other |
| --- | --- | --- | --- | --- | --- | --- | --- |
| 0 | **HITOS** | 2023-11-15 → 2023-12-01 (+16d) |  |  |  |  |  |
| A1010 | INICIO DE PLAZO CONTRACTUAL - ACCESO AL SITIO |  |  |  |  | KICK OFF MEETING SS+14d → none |  |
| A1015 | INICIO DE EXCAVACIÓN |  |  |  | 259d → 302d | A1010 SS+4d → A1010 SS+5d |  |
| A1016 | INICIO DE RELLENO DE DIQUE |  |  |  | 369d → 430d | A1015 SS+19d → A1015 SS+22d |  |
| A1040 | INSTALACIONES PROVISIONALES PARA LA OBRA |  |  | 4d → 5d |  | A1010 SS, CARTEL DE IDENTIFICACIÓN OBRA 4.80 x 3.60 m. SS → A1010 SS | resources HH [32 h] → HH [40 h] |
| A1050 | MANTENIMIENTO DE TRÁNSITO Y SEGURIDAD VIAL |  |  | 154d → 180d | 238d → 277d |  | resources HH [1232 h] → HH [1440 h] |
| A1110 | MOVILIZACION DE EQUIPOS |  |  | 4d → 5d |  | A1010 → A1010 SS | resources HH [32 h] → none |
| A1070 | TOPOGRAFÍA Y GEOREFERENCIACIÓN | 2023-12-06 → 2023-12-07 (+1d) |  | 387d → 450d |  | A1040 → A1040 FS+1d | resources HH [3096 h] → HH [3600 h] |
| A1080 | DESMOVILIZACION DE EQUIPOS | 2025-02-22 → 2025-02-23 (+1d) |  |  |  |  |  |
| A1090 | ROCE Y LIMPIEZA DE MALEZA |  |  | 30d → 35d | 259d → 302d |  | resources HH [240 h] → HH [280 h] |
| A1100 | REHABILITACIÓN DE VÍAS EXISTENTES |  |  | 129d → 150d | 259d → 302d |  | resources HH [1032 h] → HH [1200 h] |
| A4650 | CONFORMACIÓN DE TERRAPLENES EN CAMINO |  |  | 30d → 35d | 356d → 415d |  | resources HH [240 h] → HH [280 h] |
| 2 | **REPOSICIÓN DE ESTRUCTURAS** | 2023-12-07 → 2023-12-08 (+1d) | 2025-01-22 → 2025-01-21 (-1d) |  |  |  |  |
| A1150 | DEMOLICIÓN DE ESTRUCTURAS EXISTENTES | 2023-12-07 → 2023-12-08 (+1d) | 2023-12-08 → 2023-12-10 (+2d) | 2d → 3d | 385d → 447d |  | resources HH [16 h] → HH [24 h] |
| A1160 | REPOSICIÓN DE PASE DE AGUA TUBO HDPE Ø=18" |  |  |  | 23d → 26d | A8440 SS → A8440 SS+21d |  |
| A1170 | REPOSICIÓN DE PASE DE AGUA TUBO HDPE Ø=36" |  | 2025-01-20 → 2025-01-19 (-1d) |  | 23d → 26d |  |  |
| A1180 | SUMINISTRO Y MONTAJE DE PANELES DE C°A° 1.9mx1.0mx0.20m EN PASE DE AGUA | 2025-01-20 → 2025-01-19 (-1d) | 2025-01-21 → 2025-01-20 (-1d) |  | 23d → 26d |  |  |
| A1190 | SUMINISTRO Y MONTAJE DE PANELES DE C°A° 1.6mx1.0mx0.20m EN PASE DE AGUA | 2025-01-20 → 2025-01-19 (-1d) | 2025-01-21 → 2025-01-20 (-1d) |  | 24d → 27d |  |  |
| A4660 | SUMINISTRO Y MONTAJE DE PANELES DE C°A° 1.8mx1.0mx0.20m EN PASE DE AGUA | 2025-01-21 → 2025-01-20 (-1d) | 2025-01-22 → 2025-01-21 (-1d) |  | 23d → 26d |  |  |
| 4 | **CABEZAL DE ENTRADA Y SALIDA** | 2025-01-23 → 2025-01-22 (-1d) |  |  |  |  |  |
| A1210 | ENCOFRADO Y DESENCOFRADO NORMAL | 2025-01-23 → 2025-01-22 (-1d) |  | 6d → 8d | 23d → 26d |  | resources HH [48 h] → HH [64 h] |
| A1200 | CONCRETO 175 Kg/Cm2 |  |  | 4d → 5d | 23d → 26d |  | resources HH [32 h] → HH [40 h] |
| 4 | **DESCOLMATACIÓN DE CAUCE Y OBRAS AUXILIARES** | 2023-12-05 → 2023-12-04 (-1d) | 2025-03-01 → 2024-12-26 (-65d) |  |  |  |  |
| 1 | **DESBROCE Y DESCOLMATACIÓN** | 2023-12-05 → 2023-12-04 (-1d) | 2025-03-01 → 2024-12-26 (-65d) |  |  |  |  |
| A1240 | DESBROCE Y LIMPIEZA EN ZONA NO BOSCOSA | 2023-12-05 → 2023-12-04 (-1d) | 2024-11-18 → 2024-09-28 (-51d) |  |  |  | resources HH [2400 h] → none |
| A1230 | DESCOLMATACIÓN DE CAUCE NATURAL DEL RÍO LACRAMARCA | 2023-12-07 → 2023-12-06 (-1d) | 2024-10-26 → 2024-09-30 (-26d) | 279d → 300d | 0d → 65d |  | resources HH [2232 h] → HH [2400 h] |
| A1880 | CONFORMACIÓN DE DESVIO EN CAUCE DE RÍO | 2023-12-11 → 2023-12-09 (-2d) | 2025-03-01 → 2024-12-26 (-65d) |  | 0d → 65d |  |  |
| A1870 | RELLENO NO ESTRUCTURAL CON MATERIAL PROPIO | 2023-12-13 → 2023-12-11 (-2d) | 2025-03-01 → 2024-12-26 (-65d) |  | 0d → 65d |  |  |
| 7 | **CRUCE VEHICULAR** | 2025-01-10 → 2024-12-21 (-20d) | 2025-02-12 → 2025-01-18 (-25d) |  |  |  |  |
| 1 | **MEJORAMIENTO DE CRUCE VEHICULAR** | 2025-01-10 → 2024-12-21 (-20d) | 2025-02-12 → 2025-01-18 (-25d) |  |  |  |  |
| A4670 | VACIADO DE CONCRETO f´c=280 Kg/cm2 | 2025-01-10 → 2024-12-21 (-20d) | 2025-01-13 → 2024-12-23 (-21d) |  | 15d → 42d |  |  |
| A4680 | VACIADO DE CONCRETO CICLÓPEO f'c=170 kg/cm2 | 2025-01-14 → 2024-12-24 (-21d) | 2025-01-16 → 2024-12-26 (-21d) |  | 15d → 42d |  |  |
| A4690 | ACERO DE REFUERZO fy=4200 kg/cm2 | 2025-01-17 → 2024-12-27 (-21d) | 2025-02-10 → 2025-01-16 (-25d) |  | 15d → 42d |  |  |
| A4700 | ENCOFRADO Y DESENCOFRADO NORMAL | 2025-01-24 → 2025-01-02 (-22d) | 2025-02-10 → 2025-01-16 (-25d) |  | 15d → 42d |  |  |
| A4710 | MONTAJE DE LOSA PREFABRICADA | 2025-01-31 → 2025-01-08 (-23d) | 2025-02-12 → 2025-01-18 (-25d) |  | 15d → 42d |  |  |
| 6 | **RAMPAS** | 2024-02-29 → 2024-01-27 (-33d) | 2025-02-28 → 2025-02-16 (-12d) |  |  |  |  |
| 1 | **CONSTRUCCION DE RAMPAS** | 2024-02-29 → 2024-01-27 (-33d) | 2025-02-28 → 2025-02-16 (-12d) |  |  |  |  |
| A1710 | EXCAVACIÓN EN TERRENO NATURAL CON EQUIPO | 2024-02-29 → 2024-01-27 (-33d) | 2025-02-28 → 2025-02-14 (-14d) | 314d → 385d | 1d → 13d |  | resources HH [2512 h] → HH [3080 h] |
| A1720 | CONFORMACIÓN DE CUERPO DE RAMPA CON MATERIAL PROPIO | 2024-03-01 → 2024-01-28 (-33d) | 2025-02-28 → 2025-02-15 (-13d) | 313d → 385d | 1d → 13d |  | resources HH [2504 h] → HH [3080 h] |
| A1730 | CONFORMACIÓN DE CORONACIÓN DE RAMPA | 2024-03-02 → 2024-01-29 (-33d) | 2025-02-28 → 2025-02-16 (-12d) | 312d → 385d | 1d → 13d |  | resources HH [2496 h] → HH [3080 h] |
| 16 | **DIQUE A2-I-03** | 2023-12-06 → 2023-12-07 (+1d) | 2025-03-01 → 2025-02-11 (-18d) |  |  |  |  |
| 2 | **DIQUE DE TIERRA COMPACTADA A2-I-03 SIN AFECTACION** | 2023-12-06 → 2023-12-07 (+1d) | 2024-02-28 → 2024-01-29 (-30d) |  |  |  |  |
| A7420 | ENTREGA DE TERRENO | 2023-12-06 → 2023-12-07 (+1d) | 2023-12-06 → 2023-12-07 (+1d) |  |  | A1040 → A1040 FS+1d |  |
| A7430 | EXCAVACIÓN EN TERRENO NATURAL CON EQUIPO | 2023-12-07 → 2023-12-08 (+1d) | 2024-02-05 → 2024-01-03 (-33d) | 52d → 27d |  |  | resources HH [416 h] → HH [216 h] |
| A7440 | EXCAVACIÓN DE UÑA CON EQUIPO | 2023-12-08 → 2023-12-11 (+3d) | 2024-02-06 → 2024-01-06 (-31d) | 52d → 27d |  | A7430 SS+1d → A7430 SS+3d | resources HH [416 h] → HH [216 h] |
| A7450 | PERFILADO EN ZONA DE CORTE TALUD DE DIQUE | 2023-12-08 → 2023-12-14 (+6d) | 2024-02-06 → 2024-01-09 (-28d) | 52d → 27d |  | A7430 SS+1d → A7430 SS+6d | resources HH [416 h] → HH [216 h] |
| A7460 | PREPARACIÓN DE FUNDACIÓN DE CUERPO DE DIQUE | 2023-12-09 → 2023-12-15 (+6d) | 2024-02-07 → 2024-01-10 (-28d) | 52d → 27d |  | A7430 SS+1d, A7450 SS+1d, A7440 SS+1d → A7430 SS+4d, A7450 SS+1d, A7440 SS+4d | resources HH [416 h] → HH [216 h] |
| A7470 | CONFORMACIÓN DE CUERPO DE DIQUE CON MATERIAL PROPIO | 2023-12-28 → 2023-12-29 (+1d) | 2024-02-26 → 2024-01-24 (-33d) | 52d → 27d |  | A7460 SS+16d → A7460 SS+14d | resources HH [416 h] → HH [216 h] |
| A7480 | GEOTEXTIL NO TEJIDO 400 G/M2, INC. COLOCACIÓN | 2023-12-28 → 2023-12-30 (+2d) | 2024-02-26 → 2024-01-25 (-32d) | 52d → 27d |  | A7470 SS → A7470 SS+1d | resources HH [416 h] → HH [216 h] |
| A7490 | PERFILADO Y COMPACTACIÓN EN ZONA DE CORTE EN CORONA | 2023-12-28 → 2023-12-31 (+3d) | 2024-02-26 → 2024-01-26 (-31d) | 52d → 27d |  | A7480 SS → A7480 SS+1d | resources HH [416 h] → HH [216 h] |
| A7500 | CONFORMACIÓN DE MATERIAL GRANULAR EN CORONA DE DIQUE | 2023-12-29 → 2024-01-01 (+3d) | 2024-02-27 → 2024-01-27 (-31d) | 52d → 27d |  |  | resources HH [416 h] → HH [216 h] |
| A7510 | COLOCACION Y ACOMODO DE ROCA EN UÑA DE DIQUE | 2023-12-29 → 2024-01-02 (+4d) | 2024-02-27 → 2024-01-28 (-30d) | 52d → 27d |  | A7500 SS → A7500 SS+1d | resources HH [416 h] → HH [216 h] |
| A7520 | COLOCACION Y ACOMODO DE ROCA EN TALUD DE DIQUE | 2023-12-29 → 2024-01-03 (+5d) | 2024-02-28 → 2024-01-29 (-30d) | 53d → 27d | 28d → 23d | A7510 SS → A7510 SS+1d | resources HH [424 h] → HH [216 h] |
| 12 | **DIQUE DE TIERRA COMPACTADA A2-I-03 CON AFECTACION** | 2024-10-30 → 2024-09-30 (-30d) | 2024-11-29 → 2024-11-01 (-28d) |  |  |  |  |
| A7540 | ENTREGA DE TERRENO | 2024-10-30 → 2024-09-30 (-30d) | 2024-10-30 → 2024-09-30 (-30d) |  | 79d → 120d |  |  |
| A7530 | EXCAVACIÓN EN TERRENO NATURAL CON EQUIPO | 2024-10-31 → 2024-10-01 (-30d) | 2024-11-16 → 2024-10-14 (-33d) | 15d → 14d | 79d → 120d |  | resources HH [120 h] → HH [112 h] |
| A7550 | EXCAVACIÓN DE UÑA CON EQUIPO | 2024-11-01 → 2024-10-03 (-29d) | 2024-11-18 → 2024-10-16 (-33d) | 15d → 14d | 80d → 122d | A7530 SS+1d → A7530 SS+2d | resources HH [120 h] → HH [112 h] |
| A7560 | PERFILADO EN ZONA DE CORTE TALUD DE DIQUE | 2024-11-02 → 2024-10-05 (-28d) | 2024-11-19 → 2024-10-18 (-32d) | 15d → 14d | 79d → 120d | A7530 SS+2d → A7530 SS+4d | resources HH [120 h] → HH [112 h] |
| A7570 | PREPARACIÓN DE FUNDACIÓN DE CUERPO DE DIQUE | 2024-11-04 → 2024-10-07 (-28d) | 2024-11-20 → 2024-10-20 (-31d) | 15d → 14d | 79d → 120d | A7530 SS+1d, A7560 SS+1d, A7550 SS+1d → A7530 SS+2d, A7560 SS+2d, A7550 SS+2d | resources HH [120 h] → HH [112 h] |
| A7580 | CONFORMACIÓN DE CUERPO DE DIQUE CON MATERIAL PROPIO | 2024-11-05 → 2024-10-09 (-27d) | 2024-11-21 → 2024-10-22 (-30d) | 15d → 14d | 79d → 120d | A7570 SS+1d → A7570 SS+2d | resources HH [120 h] → HH [112 h] |
| A7590 | GEOTEXTIL NO TEJIDO 400 G/M2, INC. COLOCACIÓN | 2024-11-06 → 2024-10-11 (-26d) | 2024-11-22 → 2024-10-24 (-29d) | 15d → 14d | 79d → 120d | A7580 SS+1d → A7580 SS+2d | resources HH [120 h] → HH [112 h] |
| A7600 | PERFILADO Y COMPACTACIÓN EN ZONA DE CORTE EN CORONA | 2024-11-07 → 2024-10-13 (-25d) | 2024-11-23 → 2024-10-26 (-28d) | 15d → 14d | 79d → 120d | A7590 SS+1d → A7590 SS+2d | resources HH [120 h] → HH [112 h] |
| A7610 | CONFORMACIÓN DE MATERIAL GRANULAR EN CORONA DE DIQUE | 2024-11-08 → 2024-10-15 (-24d) | 2024-11-25 → 2024-10-28 (-28d) | 15d → 14d | 79d → 120d | A7600 SS+1d → A7600 SS+2d | resources HH [120 h] → HH [112 h] |
| A7620 | COLOCACION Y ACOMODO DE ROCA EN UÑA DE DIQUE | 2024-11-11 → 2024-10-17 (-25d) | 2024-11-27 → 2024-10-30 (-28d) | 15d → 14d | 79d → 120d |  | resources HH [120 h] → HH [112 h] |
| A7630 | COLOCACION Y ACOMODO DE ROCA EN TALUD DE DIQUE | 2024-11-13 → 2024-10-19 (-25d) | 2024-11-29 → 2024-11-01 (-28d) | 15d → 14d | 79d → 120d |  | resources HH [120 h] → HH [112 h] |
| 14 | **DIQUE DE TIERRA COMPACTADA A2-I-03 POR LIBERAR** | 2025-01-10 → 2024-12-21 (-20d) | 2025-03-01 → 2025-02-11 (-18d) |  |  |  |  |
| A7640 | ENTREGA DE TERRENO | 2025-01-10 → 2024-12-21 (-20d) | 2025-01-10 → 2024-12-21 (-20d) |  | 0d → 18d |  |  |
| A7650 | EXCAVACIÓN EN TERRENO NATURAL CON EQUIPO | 2025-01-11 → 2024-12-22 (-20d) | 2025-02-18 → 2025-01-23 (-26d) |  | 0d → 18d |  |  |
| A7660 | EXCAVACIÓN DE UÑA CON EQUIPO | 2025-01-14 → 2024-12-24 (-21d) | 2025-02-20 → 2025-01-25 (-26d) |  | 0d → 20d |  |  |
| A7670 | PERFILADO EN ZONA DE CORTE TALUD DE DIQUE | 2025-01-14 → 2024-12-26 (-19d) | 2025-02-20 → 2025-01-27 (-24d) |  | 0d → 18d | A7650 SS+2d → A7650 SS+4d |  |

| ID | Task | Start | Finish | Duration | Total float | Predecessors | Other |
| --- | --- | --- | --- | --- | --- | --- | --- |
| A7680 | PREPARACIÓN DE FUNDACIÓN DE CUERPO DE DIQUE | 2025-01-15 → 2024-12-28 (-18d) | 2025-02-21 → 2025-01-29 (-23d) |  | 0d → 18d | A7650 SS+1d, A7670 SS+1d, A7660 SS+1d → A7650 SS+1d, A7670 SS+2d, A7660 SS+2d |  |
| A7690 | CONFORMACIÓN DE CUERPO DE DIQUE CON MATERIAL PROPIO | 2025-01-16 → 2024-12-30 (-17d) | 2025-02-22 → 2025-01-31 (-22d) |  | 0d → 18d | A7680 SS+1d → A7680 SS+2d |  |
| A7700 | GEOTEXTIL NO TEJIDO 400 G/M2, INC. COLOCACIÓN | 2025-01-18 → 2025-01-02 (-16d) | 2025-02-25 → 2025-02-03 (-22d) |  | 0d → 18d | A7690 SS+2d → A7690 SS+3d |  |
| A7710 | PERFILADO Y COMPACTACIÓN EN ZONA DE CORTE EN CORONA | 2025-01-18 → 2025-01-04 (-14d) | 2025-02-25 → 2025-02-05 (-20d) |  | 0d → 18d | A7700 SS → A7700 SS+2d |  |
| A7720 | CONFORMACIÓN DE MATERIAL GRANULAR EN CORONA DE DIQUE | 2025-01-20 → 2025-01-06 (-14d) | 2025-02-26 → 2025-02-07 (-19d) |  | 0d → 18d | A7710 SS+1d → A7710 SS+2d |  |
| A7730 | COLOCACION Y ACOMODO DE ROCA EN UÑA DE DIQUE | 2025-01-22 → 2025-01-08 (-14d) | 2025-02-28 → 2025-02-09 (-19d) |  | 0d → 18d |  |  |
| A7740 | COLOCACION Y ACOMODO DE ROCA EN TALUD DE DIQUE | 2025-01-23 → 2025-01-10 (-13d) | 2025-03-01 → 2025-02-11 (-18d) |  | 0d → 18d | A7730 SS+1d → A7730 SS+2d |  |
| 8 | **DIQUE A2-I-2** | 2024-01-31 → 2024-01-26 (-5d) | 2024-10-28 → 2024-09-14 (-44d) |  |  |  |  |
| 6 | **DIQUE DE TIERRA COMPACTADA A2-I-02 SIN AFECTACION** | 2024-01-31 → 2024-01-26 (-5d) | 2024-05-04 → 2024-04-17 (-17d) |  |  |  |  |
| A7750 | ENTREGA DE TERRENO | 2024-01-31 → 2024-01-26 (-5d) | 2024-01-31 → 2024-01-26 (-5d) |  |  |  |  |
| A7760 | EXCAVACIÓN EN TERRENO NATURAL CON EQUIPO | 2024-02-01 → 2024-01-27 (-5d) | 2024-04-24 → 2024-04-06 (-18d) | 72d → 71d |  |  | resources HH [576 h] → HH [568 h] |
| A7770 | EXCAVACIÓN DE UÑA CON EQUIPO | 2024-02-02 → 2024-01-28 (-5d) | 2024-04-25 → 2024-04-07 (-18d) | 72d → 71d | 0d → 1d |  | resources HH [576 h] → HH [568 h] |
| A7780 | PERFILADO EN ZONA DE CORTE TALUD DE DIQUE | 2024-02-02 → 2024-01-29 (-4d) | 2024-04-25 → 2024-04-08 (-17d) | 72d → 71d | 1d → 0d | A7760 SS+1d → A7760 SS+2d | resources HH [576 h] → HH [568 h] |
| A7790 | PREPARACIÓN DE FUNDACIÓN DE CUERPO DE DIQUE | 2024-02-03 → 2024-01-30 (-4d) | 2024-04-26 → 2024-04-09 (-17d) | 72d → 71d | 0d → 1d | A7760 SS+1d, A7780 SS, A7770 SS+1d → A7760 SS+1d, A7780 SS, A7770 SS+2d | resources HH [576 h] → HH [568 h] |
| A7800 | PEDRAPLEN e=60 cm | 2024-02-03 → 2024-01-31 (-3d) | 2024-04-26 → 2024-04-10 (-16d) | 72d → 71d | 1d → 0d | A7780 FF+1d → A7780 FF+2d | resources HH [576 h] → HH [568 h] |
| A7810 | PEDRAPLEN e=30 cm | 2024-02-03 → 2024-02-01 (-2d) | 2024-04-26 → 2024-04-11 (-15d) | 72d → 71d | 1d → 0d | A7800 FF → A7800 FF+1d | resources HH [576 h] → HH [568 h] |
| A7820 | CONFORMACIÓN DE CUERPO DE DIQUE CON MATERIAL PROPIO | 2024-02-05 → 2024-02-01 (-4d) | 2024-04-27 → 2024-04-11 (-16d) | 72d → 71d |  |  | resources HH [576 h] → HH [568 h] |
| A7830 | CONFORMACIÓN DE RELLENO NO ESTRUCTURAL CON MATERIAL PROPIO | 2024-02-06 → 2024-02-02 (-4d) | 2024-04-29 → 2024-04-12 (-17d) | 72d → 71d |  |  | resources HH [576 h] → HH [568 h] |
| A7840 | GEOTEXTIL NO TEJIDO 400 G/M2, INC. COLOCACIÓN | 2024-02-07 → 2024-02-03 (-4d) | 2024-04-30 → 2024-04-13 (-17d) | 72d → 71d |  |  | resources HH [576 h] → HH [568 h] |
| A7850 | PERFILADO Y COMPACTACIÓN EN ZONA DE CORTE EN CORONA | 2024-02-08 → 2024-02-04 (-4d) | 2024-05-01 → 2024-04-14 (-17d) | 72d → 71d |  |  | resources HH [576 h] → HH [568 h] |
| A7860 | CONFORMACIÓN DE MATERIAL GRANULAR EN CORONA DE DIQUE | 2024-02-09 → 2024-02-05 (-4d) | 2024-05-02 → 2024-04-15 (-17d) | 72d → 71d |  |  | resources HH [576 h] → HH [568 h] |
| A7870 | COLOCACION Y ACOMODO DE ROCA EN UÑA DE DIQUE | 2024-02-10 → 2024-02-06 (-4d) | 2024-05-03 → 2024-04-16 (-17d) | 72d → 71d |  |  | resources HH [576 h] → HH [568 h] |
| A7880 | COLOCACION Y ACOMODO DE ROCA EN TALUD DE DIQUE | 2024-02-12 → 2024-02-07 (-5d) | 2024-05-04 → 2024-04-17 (-17d) | 72d → 71d |  |  | resources HH [576 h] → HH [568 h] |
| 7 | **DIQUE DE TIERRA COMPACTADA A2-I-02 CON AFECTACION** | 2024-08-31 → 2024-07-29 (-33d) | 2024-10-12 → 2024-09-02 (-40d) |  |  |  |  |
| A7890 | ENTREGA DE TERRENO | 2024-08-31 → 2024-07-29 (-33d) | 2024-08-31 → 2024-07-29 (-33d) |  | 107d → 0d |  |  |
| A7900 | EXCAVACIÓN EN TERRENO NATURAL CON EQUIPO | 2024-09-02 → 2024-07-30 (-34d) | 2024-09-30 → 2024-08-22 (-39d) | 25d → 24d | 107d → 0d |  | resources HH [200 h] → HH [192 h] |
| A7910 | EXCAVACIÓN DE UÑA CON EQUIPO | 2024-09-03 → 2024-07-31 (-34d) | 2024-10-01 → 2024-08-23 (-39d) | 25d → 24d | 108d → 1d |  | resources HH [200 h] → HH [192 h] |
| A7920 | PERFILADO EN ZONA DE CORTE TALUD DE DIQUE | 2024-09-04 → 2024-08-01 (-34d) | 2024-10-02 → 2024-08-24 (-39d) | 25d → 24d | 107d → 0d |  | resources HH [200 h] → HH [192 h] |
| A7930 | PREPARACIÓN DE FUNDACIÓN DE CUERPO DE DIQUE | 2024-09-04 → 2024-08-01 (-34d) | 2024-10-02 → 2024-08-24 (-39d) | 25d → 24d | 108d → 1d |  | resources HH [200 h] → HH [192 h] |
| A7940 | PEDRAPLEN e=60 cm | 2024-09-05 → 2024-08-02 (-34d) | 2024-10-03 → 2024-08-25 (-39d) | 25d → 24d | 107d → 0d |  | resources HH [200 h] → HH [192 h] |
| A7950 | CONFORMACIÓN DE CUERPO DE DIQUE CON MATERIAL PROPIO | 2024-09-06 → 2024-08-03 (-34d) | 2024-10-04 → 2024-08-26 (-39d) | 25d → 24d | 107d → 0d |  | resources HH [200 h] → HH [192 h] |
| A7960 | PEDRAPLEN e=30 cm | 2024-09-06 → 2024-08-03 (-34d) | 2024-10-04 → 2024-08-26 (-39d) | 25d → 24d | 107d → 0d |  | resources HH [200 h] → HH [192 h] |
| A7970 | CONFORMACIÓN DE RELLENO NO ESTRUCTURAL CON MATERIAL PROPIO | 2024-09-07 → 2024-08-04 (-34d) | 2024-10-05 → 2024-08-27 (-39d) | 25d → 24d | 107d → 0d |  | resources HH [200 h] → HH [192 h] |
| A7980 | GEOTEXTIL NO TEJIDO 400 G/M2, INC. COLOCACIÓN | 2024-09-09 → 2024-08-05 (-35d) | 2024-10-07 → 2024-08-28 (-40d) | 25d → 24d | 107d → 0d |  | resources HH [200 h] → HH [192 h] |
| A7990 | PERFILADO Y COMPACTACIÓN EN ZONA DE CORTE EN CORONA | 2024-09-11 → 2024-08-07 (-35d) | 2024-10-09 → 2024-08-30 (-40d) | 25d → 24d | 107d → 0d |  | resources HH [200 h] → HH [192 h] |
| A8000 | CONFORMACIÓN DE MATERIAL GRANULAR EN CORONA DE DIQUE | 2024-09-12 → 2024-08-08 (-35d) | 2024-10-10 → 2024-08-31 (-40d) | 25d → 24d | 107d → 0d |  | resources HH [200 h] → HH [192 h] |
| A8010 | COLOCACION Y ACOMODO DE ROCA EN UÑA DE DIQUE | 2024-09-13 → 2024-08-09 (-35d) | 2024-10-11 → 2024-09-01 (-40d) | 25d → 24d | 107d → 0d |  | resources HH [200 h] → HH [192 h] |
| A8020 | COLOCACION Y ACOMODO DE ROCA EN TALUD DE DIQUE | 2024-09-14 → 2024-08-10 (-35d) | 2024-10-12 → 2024-09-02 (-40d) | 25d → 24d | 107d → 0d |  | resources HH [200 h] → HH [192 h] |
| 11 | **DIQUE DE TIERRA COMPACTADA A2-I-02 POR LIBERAR** | 2024-10-14 → 2024-09-03 (-41d) | 2024-10-28 → 2024-09-14 (-44d) |  |  |  |  |
| A8030 | ENTREGA DE TERRENO | 2024-10-14 → 2024-09-03 (-41d) | 2024-10-14 → 2024-09-03 (-41d) |  | 107d → 0d |  |  |
| A8040 | EXCAVACIÓN EN TERRENO NATURAL CON EQUIPO | 2024-10-15 → 2024-09-04 (-41d) | 2024-10-19 → 2024-09-06 (-43d) | 5d → 3d | 107d → 0d |  | resources HH [40 h] → HH [24 h] |
| A8050 | EXCAVACIÓN DE UÑA CON EQUIPO | 2024-10-16 → 2024-09-05 (-41d) | 2024-10-21 → 2024-09-07 (-44d) | 5d → 3d | 107d → 0d |  | resources HH [40 h] → HH [24 h] |
| A8060 | PERFILADO EN ZONA DE CORTE TALUD DE DIQUE | 2024-10-16 → 2024-09-05 (-41d) | 2024-10-21 → 2024-09-07 (-44d) | 5d → 3d | 108d → 1d |  | resources HH [40 h] → HH [24 h] |
| A8070 | PREPARACIÓN DE FUNDACIÓN DE CUERPO DE DIQUE | 2024-10-17 → 2024-09-06 (-41d) | 2024-10-22 → 2024-09-08 (-44d) | 5d → 3d | 107d → 0d |  | resources HH [40 h] → HH [24 h] |
| A8080 | PEDRAPLEN e=60 cm | 2024-10-17 → 2024-09-06 (-41d) | 2024-10-22 → 2024-09-08 (-44d) | 5d → 3d | 108d → 1d |  | resources HH [40 h] → HH [24 h] |
| A8090 | PEDRAPLEN e=30 cm | 2024-10-17 → 2024-09-06 (-41d) | 2024-10-22 → 2024-09-08 (-44d) | 5d → 3d | 108d → 1d |  | resources HH [40 h] → HH [24 h] |
| A8100 | CONFORMACIÓN DE CUERPO DE DIQUE CON MATERIAL PROPIO | 2024-10-18 → 2024-09-07 (-41d) | 2024-10-23 → 2024-09-09 (-44d) | 5d → 3d | 107d → 0d |  | resources HH [40 h] → HH [24 h] |
| A8110 | CONFORMACIÓN DE RELLENO NO ESTRUCTURAL CON MATERIAL PROPIO | 2024-10-19 → 2024-09-08 (-41d) | 2024-10-24 → 2024-09-10 (-44d) | 5d → 3d | 107d → 0d |  | resources HH [40 h] → HH [24 h] |
| A8120 | GEOTEXTIL NO TEJIDO 400 G/M2, INC. COLOCACIÓN | 2024-10-21 → 2024-09-09 (-42d) | 2024-10-25 → 2024-09-11 (-44d) | 5d → 3d | 107d → 0d |  | resources HH [40 h] → HH [24 h] |
| A8130 | PERFILADO Y COMPACTACIÓN EN ZONA DE CORTE EN CORONA | 2024-10-22 → 2024-09-10 (-42d) | 2024-10-26 → 2024-09-12 (-44d) | 5d → 3d | 107d → 0d |  | resources HH [40 h] → HH [24 h] |
| A8140 | CONFORMACIÓN DE MATERIAL GRANULAR EN CORONA DE DIQUE | 2024-10-23 → 2024-09-11 (-42d) | 2024-10-26 → 2024-09-13 (-43d) | 4d → 3d | 107d → 0d |  | resources HH [32 h] → HH [24 h] |
| A8150 | COLOCACION Y ACOMODO DE ROCA EN UÑA DE DIQUE | 2024-10-24 → 2024-09-12 (-42d) | 2024-10-28 → 2024-09-14 (-44d) | 4d → 3d | 107d → 0d |  | resources HH [32 h] → HH [24 h] |
| A8160 | COLOCACION Y ACOMODO DE ROCA EN TALUD DE DIQUE | 2024-10-24 → 2024-09-12 (-42d) | 2024-10-28 → 2024-09-14 (-44d) | 4d → 3d | 107d → 0d |  | resources HH [32 h] → HH [24 h] |
| 10 | **DIQUE A2-I-1** | 2024-08-31 → 2024-07-29 (-33d) | 2025-02-07 → 2025-03-01 (+22d) |  |  |  |  |
| 9 | **DIQUE DE TIERRA COMPACTADA A2-I-01 SIN AFECTACION** | 2024-08-31 → 2024-07-29 (-33d) | 2024-10-29 → 2024-09-29 (-30d) |  |  |  |  |
| A8500 | ENTREGA DE TERRENO | 2024-08-31 → 2024-07-29 (-33d) | 2024-08-31 → 2024-07-29 (-33d) |  | 79d → 120d |  |  |
| A8510 | EXCAVACIÓN EN TERRENO NATURAL CON EQUIPO | 2024-09-02 → 2024-07-30 (-34d) | 2024-10-18 → 2024-09-07 (-41d) | 41d → 40d | 79d → 120d |  | resources HH [328 h] → HH [320 h] |
| A8520 | EXCAVACIÓN DE UÑA CON EQUIPO | 2024-09-03 → 2024-07-31 (-34d) | 2024-10-19 → 2024-09-08 (-41d) | 41d → 40d | 79d → 125d |  | resources HH [328 h] → HH [320 h] |
| A8530 | PERFILADO EN ZONA DE CORTE TALUD DE DIQUE | 2024-09-03 → 2024-08-01 (-33d) | 2024-10-19 → 2024-09-09 (-40d) | 41d → 40d | 80d → 120d | A8510 SS+1d → A8510 SS+2d | resources HH [328 h] → HH [320 h] |
| A8540 | PREPARACIÓN DE FUNDACIÓN DE CUERPO DE DIQUE | 2024-09-04 → 2024-08-02 (-33d) | 2024-10-21 → 2024-09-10 (-41d) | 41d → 40d | 79d → 125d | A8510 SS+1d, A8530 SS, A8520 SS+1d → A8510 SS+2d, A8530 SS, A8520 SS+2d | resources HH [328 h] → HH [320 h] |
| A8550 | PEDRAPLEN e=60 cm | 2024-09-04 → 2024-08-05 (-30d) | 2024-10-21 → 2024-09-13 (-38d) | 41d → 40d | 80d → 120d | A8530 FF+1d → A8530 FF+4d | resources HH [328 h] → HH [320 h] |
| A8560 | PEDRAPLEN e=30 cm | 2024-09-04 → 2024-08-09 (-26d) | 2024-10-21 → 2024-09-17 (-34d) | 41d → 40d | 80d → 120d | A8550 FF → A8550 FF+4d | resources HH [328 h] → HH [320 h] |
| A8570 | CONFORMACIÓN DE CUERPO DE DIQUE CON MATERIAL PROPIO | 2024-09-05 → 2024-08-09 (-27d) | 2024-10-22 → 2024-09-17 (-35d) | 41d → 40d | 79d → 120d | A8540 SS+1d, A8560 SS → A8540 SS+2d, A8560 SS | resources HH [328 h] → HH [320 h] |
| A8580 | CONFORMACIÓN DE RELLENO NO ESTRUCTURAL CON MATERIAL PROPIO | 2024-09-06 → 2024-08-11 (-26d) | 2024-10-23 → 2024-09-19 (-34d) | 41d → 40d | 79d → 120d | A8570 SS+1d → A8570 SS+2d | resources HH [328 h] → HH [320 h] |
| A8590 | GEOTEXTIL NO TEJIDO 400 G/M2, INC. COLOCACIÓN | 2024-09-07 → 2024-08-13 (-25d) | 2024-10-24 → 2024-09-21 (-33d) | 41d → 40d | 79d → 120d | A8570 SS, A8580 SS+1d → A8570 SS, A8580 SS+2d | resources HH [328 h] → HH [320 h] |
| A8600 | PERFILADO Y COMPACTACIÓN EN ZONA DE CORTE EN CORONA | 2024-09-09 → 2024-08-15 (-25d) | 2024-10-25 → 2024-09-23 (-32d) | 41d → 40d | 79d → 120d | A8590 SS+1d → A8590 SS+2d | resources HH [328 h] → HH [320 h] |
| A8610 | CONFORMACIÓN DE MATERIAL GRANULAR EN CORONA DE DIQUE | 2024-09-10 → 2024-08-17 (-24d) | 2024-10-26 → 2024-09-25 (-31d) | 41d → 40d | 79d → 120d | A8600 SS+1d → A8600 SS+2d | resources HH [328 h] → HH [320 h] |
| A8620 | COLOCACION Y ACOMODO DE ROCA EN UÑA DE DIQUE | 2024-09-11 → 2024-08-19 (-23d) | 2024-10-28 → 2024-09-27 (-31d) | 41d → 40d | 79d → 120d | A8610 SS+1d → A8610 SS+2d | resources HH [328 h] → HH [320 h] |
| A8630 | COLOCACION Y ACOMODO DE ROCA EN TALUD DE DIQUE | 2024-09-12 → 2024-08-21 (-22d) | 2024-10-29 → 2024-09-29 (-30d) | 41d → 40d | 79d → 120d | A8620 SS+1d → A8620 SS+2d | resources HH [328 h] → HH [320 h] |
| 8 | **DIQUE DE TIERRA COMPACTADA A2-I-01B SIN AFECTACION** | 2024-08-31 → 2024-07-29 (-33d) | 2024-09-12 → 2024-08-12 (-31d) |  |  |  |  |

| ID | Task | Start | Finish | Duration | Total float | Predecessors | Other |
| --- | --- | --- | --- | --- | --- | --- | --- |
| A8640 | ENTREGA DE TERRENO | 2024-08-31 → 2024-07-29 (-33d) | 2024-08-31 → 2024-07-29 (-33d) |  | 0d → 175d |  |  |
| A8650 | EXCAVACIÓN EN TERRENO NATURAL CON EQUIPO | 2024-09-02 → 2024-07-30 (-34d) | 2024-09-07 → 2024-08-03 (-35d) | 6d → 5d | 0d → 175d |  | resources HH [48 h] → HH [40 h] |
| A8660 | EXCAVACIÓN DE UÑA CON EQUIPO | 2024-09-03 → 2024-07-31 (-34d) | 2024-09-09 → 2024-08-04 (-36d) | 6d → 5d | 0d → 176d |  | resources HH [48 h] → HH [40 h] |
| A8670 | PERFILADO EN ZONA DE CORTE TALUD DE DIQUE | 2024-09-03 → 2024-08-01 (-33d) | 2024-09-09 → 2024-08-05 (-35d) | 6d → 5d | 0d → 175d | A8650 SS+1d → A8650 SS+2d | resources HH [48 h] → HH [40 h] |
| A8680 | PREPARACIÓN DE FUNDACIÓN DE CUERPO DE DIQUE | 2024-09-04 → 2024-08-02 (-33d) | 2024-09-10 → 2024-08-06 (-35d) | 6d → 5d | 0d → 175d |  | resources HH [48 h] → HH [40 h] |
| A8690 | CONFORMACIÓN DE CUERPO DE DIQUE CON MATERIAL PROPIO | 2024-09-05 → 2024-08-03 (-33d) | 2024-09-11 → 2024-08-07 (-35d) | 6d → 5d | 0d → 175d |  | resources HH [48 h] → HH [40 h] |
| A8700 | GEOTEXTIL NO TEJIDO 400 G/M2, INC. COLOCACIÓN | 2024-09-05 → 2024-08-04 (-32d) | 2024-09-11 → 2024-08-08 (-34d) | 6d → 5d | 0d → 175d | A8690 SS → A8690 SS+1d | resources HH [48 h] → HH [40 h] |
| A8710 | PERFILADO Y COMPACTACIÓN EN ZONA DE CORTE EN CORONA | 2024-09-05 → 2024-08-05 (-31d) | 2024-09-11 → 2024-08-09 (-33d) | 6d → 5d | 0d → 175d | A8700 SS → A8700 SS+1d | resources HH [48 h] → HH [40 h] |
| A8720 | CONFORMACIÓN DE MATERIAL GRANULAR EN CORONA DE DIQUE | 2024-09-06 → 2024-08-06 (-31d) | 2024-09-12 → 2024-08-10 (-33d) | 6d → 5d | 0d → 175d |  | resources HH [48 h] → HH [40 h] |
| A8730 | COLOCACION Y ACOMODO DE ROCA EN UÑA DE DIQUE | 2024-09-06 → 2024-08-07 (-30d) | 2024-09-12 → 2024-08-11 (-32d) | 6d → 5d | 0d → 175d | A8720 SS → A8720 SS+1d | resources HH [48 h] → HH [40 h] |
| A8740 | COLOCACION Y ACOMODO DE ROCA EN TALUD DE DIQUE | 2024-09-06 → 2024-08-08 (-29d) | 2024-09-12 → 2024-08-12 (-31d) | 6d → 5d | 0d → 175d | A8730 SS → A8730 SS+1d | resources HH [48 h] → HH [40 h] |
| 15 | **DIQUE DE TIERRA COMPACTADA A2-I-01 POR LIBERAR** | 2025-01-10 → 2025-01-25 (+15d) | 2025-02-07 → 2025-03-01 (+22d) |  |  |  |  |
| A8750 | ENTREGA DE TERRENO | 2025-01-10 → 2025-01-25 (+15d) | 2025-01-10 → 2025-01-25 (+15d) |  | 19d → 0d | A9300 → A8490 |  |
| A8760 | EXCAVACIÓN EN TERRENO NATURAL CON EQUIPO | 2025-01-11 → 2025-01-26 (+15d) | 2025-01-25 → 2025-02-04 (+10d) | 13d → 10d | 19d → 0d |  | resources HH [104 h] → HH [80 h] |
| A8770 | EXCAVACIÓN DE UÑA CON EQUIPO | 2025-01-13 → 2025-01-28 (+15d) | 2025-01-27 → 2025-02-06 (+10d) | 13d → 10d | 19d → 6d | A8760 SS+1d → A8760 SS+2d | resources HH [104 h] → HH [80 h] |
| A8780 | PERFILADO EN ZONA DE CORTE TALUD DE DIQUE | 2025-01-13 → 2025-01-29 (+16d) | 2025-01-27 → 2025-02-07 (+11d) | 13d → 10d | 20d → 0d | A8760 SS+1d → A8760 SS+3d | resources HH [104 h] → HH [80 h] |
| A8790 | PREPARACIÓN DE FUNDACIÓN DE CUERPO DE DIQUE | 2025-01-14 → 2025-01-31 (+17d) | 2025-01-28 → 2025-02-09 (+12d) | 13d → 10d | 19d → 6d | A8760 SS+2d, A8780 SS, A8770 SS+1d → A8760 SS+3d, A8780 SS, A8770 SS+3d | resources HH [104 h] → HH [80 h] |
| A8800 | PEDRAPLEN e=60 cm | 2025-01-15 → 2025-02-02 (+18d) | 2025-01-29 → 2025-02-11 (+13d) | 13d → 10d | 20d → 0d | A8780 FF+2d → A8780 FF+4d | resources HH [104 h] → HH [80 h] |
| A8810 | PEDRAPLEN e=30 cm | 2025-01-15 → 2025-02-04 (+20d) | 2025-01-29 → 2025-02-13 (+15d) | 13d → 10d | 20d → 0d | A8800 FF → A8800 FF+2d | resources HH [104 h] → HH [80 h] |
| A8820 | CONFORMACIÓN DE CUERPO DE DIQUE CON MATERIAL PROPIO | 2025-01-16 → 2025-02-06 (+21d) | 2025-01-30 → 2025-02-15 (+16d) | 13d → 10d | 19d → 0d | A8790 SS+2d, A8810 SS → A8790 SS, A8810 SS+2d | resources HH [104 h] → HH [80 h] |
| A8830 | CONFORMACIÓN DE RELLENO NO ESTRUCTURAL CON MATERIAL PROPIO | 2025-01-17 → 2025-02-08 (+22d) | 2025-01-31 → 2025-02-17 (+17d) | 13d → 10d | 19d → 0d | A8820 SS+1d → A8820 SS+2d | resources HH [104 h] → HH [80 h] |
| A8840 | GEOTEXTIL NO TEJIDO 400 G/M2, INC. COLOCACIÓN | 2025-01-18 → 2025-02-11 (+24d) | 2025-02-01 → 2025-02-20 (+19d) | 13d → 10d | 19d → 0d | A8820 SS, A8830 SS+1d → A8820 SS, A8830 SS+3d | resources HH [104 h] → HH [80 h] |
| A8850 | PERFILADO Y COMPACTACIÓN EN ZONA DE CORTE EN CORONA | 2025-01-20 → 2025-02-14 (+25d) | 2025-02-03 → 2025-02-23 (+20d) | 13d → 10d | 19d → 0d | A8840 SS+1d → A8840 SS+3d | resources HH [104 h] → HH [80 h] |
| A8860 | CONFORMACIÓN DE MATERIAL GRANULAR EN CORONA DE DIQUE | 2025-01-21 → 2025-02-17 (+27d) | 2025-02-04 → 2025-02-26 (+22d) | 13d → 10d | 19d → 0d | A8850 SS+1d → A8850 SS+3d | resources HH [104 h] → HH [80 h] |
| A8870 | COLOCACION Y ACOMODO DE ROCA EN UÑA DE DIQUE | 2025-01-23 → 2025-02-19 (+27d) | 2025-02-06 → 2025-02-28 (+22d) | 13d → 10d | 19d → 0d |  | resources HH [104 h] → HH [80 h] |
| A8880 | COLOCACION Y ACOMODO DE ROCA EN TALUD DE DIQUE | 2025-01-24 → 2025-02-20 (+27d) | 2025-02-07 → 2025-03-01 (+22d) | 13d → 10d | 19d → 0d |  | resources HH [104 h] → HH [80 h] |
| 9 | **DIQUE A2-D-2** |  | 2025-02-18 → 2025-01-24 (-25d) |  |  |  |  |
| 1 | **DIQUE DE TIERRA COMPACTADA A2-D-02 SIN AFECTACIÓN** |  | 2024-01-30 → 2024-01-25 (-5d) |  |  |  |  |
| A8180 | EXCAVACIÓN EN TERRENO NATURAL CON EQUIPO |  | 2024-01-04 → 2023-12-30 (-5d) | 25d → 24d |  |  | resources HH [200 h] → HH [192 h] |
| A8190 | EXCAVACIÓN DE UÑA CON EQUIPO |  | 2024-01-05 → 2023-12-31 (-5d) | 25d → 24d | 0d → 1d |  | resources HH [200 h] → HH [192 h] |
| A8200 | PERFILADO EN ZONA DE CORTE TALUD DE DIQUE | 2023-12-08 → 2023-12-09 (+1d) | 2024-01-05 → 2024-01-01 (-4d) | 25d → 24d |  | A8180 SS+1d → A8180 SS+2d | resources HH [200 h] → HH [192 h] |
| A8210 | PREPARACIÓN DE FUNDACIÓN DE CUERPO DE DIQUE | 2023-12-09 → 2023-12-10 (+1d) | 2024-01-06 → 2024-01-02 (-4d) | 25d → 24d |  |  | resources HH [200 h] → HH [192 h] |
| A8220 | CONFORMACIÓN DE CUERPO DE DIQUE CON MATERIAL PROPIO | 2023-12-28 → 2023-12-29 (+1d) | 2024-01-25 → 2024-01-21 (-4d) | 25d → 24d |  | A8210 SS+16d → A8210 SS+19d | resources HH [200 h] → HH [192 h] |
| A8230 | GEOTEXTIL NO TEJIDO 400 G/M2, INC. COLOCACIÓN | 2023-12-28 → 2023-12-29 (+1d) | 2024-01-25 → 2024-01-21 (-4d) | 25d → 24d |  |  | resources HH [200 h] → HH [192 h] |
| A8240 | PERFILADO Y COMPACTACIÓN EN ZONA DE CORTE EN CORONA | 2023-12-29 → 2023-12-30 (+1d) | 2024-01-26 → 2024-01-22 (-4d) | 25d → 24d |  |  | resources HH [200 h] → HH [192 h] |
| A8250 | CONFORMACIÓN DE MATERIAL GRANULAR EN CORONA DE DIQUE | 2023-12-30 → 2023-12-31 (+1d) | 2024-01-27 → 2024-01-23 (-4d) | 25d → 24d |  |  | resources HH [200 h] → HH [192 h] |
| A8260 | COLOCACION Y ACOMODO DE ROCA EN UÑA DE DIQUE |  | 2024-01-29 → 2024-01-24 (-5d) | 25d → 24d |  |  | resources HH [200 h] → HH [192 h] |
| A8270 | COLOCACION Y ACOMODO DE ROCA EN TALUD DE DIQUE |  | 2024-01-30 → 2024-01-25 (-5d) | 25d → 24d |  |  | resources HH [200 h] → HH [192 h] |
| 3 | **DIQUE DE TIERRA COMPACTADA A2-D-02 CON AFECTACION** | 2024-09-13 → 2024-08-13 (-31d) | 2024-10-07 → 2024-09-07 (-30d) |  |  |  |  |
| A8280 | ENTREGA DE TERRENO | 2024-09-13 → 2024-08-13 (-31d) | 2024-09-13 → 2024-08-13 (-31d) |  | 0d → 175d |  |  |
| A8290 | EXCAVACIÓN EN TERRENO NATURAL CON EQUIPO | 2024-09-14 → 2024-08-14 (-31d) | 2024-10-02 → 2024-08-29 (-34d) |  | 0d → 175d |  |  |
| A8300 | EXCAVACIÓN DE UÑA CON EQUIPO | 2024-09-16 → 2024-08-15 (-32d) | 2024-10-03 → 2024-08-30 (-34d) |  | 0d → 176d |  |  |
| A8310 | PERFILADO EN ZONA DE CORTE TALUD DE DIQUE | 2024-09-16 → 2024-08-16 (-31d) | 2024-10-03 → 2024-08-31 (-33d) |  | 0d → 175d | A8290 SS+1d → A8290 SS+2d |  |
| A8320 | PREPARACIÓN DE FUNDACIÓN DE CUERPO DE DIQUE | 2024-09-17 → 2024-08-17 (-31d) | 2024-10-04 → 2024-09-01 (-33d) |  | 0d → 175d |  |  |
| A8330 | CONFORMACIÓN DE CUERPO DE DIQUE CON MATERIAL PROPIO | 2024-09-18 → 2024-08-18 (-31d) | 2024-10-05 → 2024-09-02 (-33d) |  | 0d → 175d |  |  |
| A8340 | GEOTEXTIL NO TEJIDO 400 G/M2, INC. COLOCACIÓN | 2024-09-18 → 2024-08-19 (-30d) | 2024-10-05 → 2024-09-03 (-32d) |  | 0d → 175d | A8330 SS → A8330 SS+1d |  |
| A8350 | PERFILADO Y COMPACTACIÓN EN ZONA DE CORTE EN CORONA | 2024-09-18 → 2024-08-20 (-29d) | 2024-10-05 → 2024-09-04 (-31d) |  | 0d → 175d | A8340 SS → A8340 SS+1d |  |
| A8360 | CONFORMACIÓN DE MATERIAL GRANULAR EN CORONA DE DIQUE | 2024-09-19 → 2024-08-21 (-29d) | 2024-10-07 → 2024-09-05 (-32d) |  | 0d → 175d |  |  |
| A8370 | COLOCACION Y ACOMODO DE ROCA EN UÑA DE DIQUE | 2024-09-19 → 2024-08-22 (-28d) | 2024-10-07 → 2024-09-06 (-31d) |  | 0d → 175d | A8360 SS → A8360 SS+1d |  |
| A8380 | COLOCACION Y ACOMODO DE ROCA EN TALUD DE DIQUE | 2024-09-19 → 2024-08-23 (-27d) | 2024-10-07 → 2024-09-07 (-30d) |  | 0d → 175d | A8370 SS → A8370 SS+1d |  |
| 13 | **DIQUE DE TIERRA COMPACTADA A2-D-02 POR LIBERAR** | 2025-01-10 → 2024-12-21 (-20d) | 2025-02-18 → 2025-01-24 (-25d) |  |  |  |  |
| A8390 | ENTREGA DE TERRENO | 2025-01-10 → 2024-12-21 (-20d) | 2025-01-10 → 2024-12-21 (-20d) |  | 10d → 0d |  |  |
| A8400 | EXCAVACIÓN EN TERRENO NATURAL CON EQUIPO | 2025-01-11 → 2024-12-22 (-20d) | 2025-01-31 → 2025-01-09 (-22d) | 18d → 19d | 10d → 0d |  | resources HH [144 h] → HH [152 h] |
| A8410 | EXCAVACIÓN DE UÑA CON EQUIPO | 2025-01-13 → 2024-12-23 (-21d) | 2025-02-01 → 2025-01-10 (-22d) | 18d → 19d | 11d → 1d |  | resources HH [144 h] → HH [152 h] |
| A8420 | PERFILADO EN ZONA DE CORTE TALUD DE DIQUE | 2025-01-14 → 2024-12-24 (-21d) | 2025-02-03 → 2025-01-11 (-23d) | 18d → 19d | 10d → 0d |  | resources HH [144 h] → HH [152 h] |
| A8430 | PREPARACIÓN DE FUNDACIÓN DE CUERPO DE DIQUE | 2025-01-15 → 2024-12-25 (-21d) | 2025-02-04 → 2025-01-12 (-23d) | 18d → 19d | 10d → 0d |  | resources HH [144 h] → HH [152 h] |
| A8440 | CONFORMACIÓN DE CUERPO DE DIQUE CON MATERIAL PROPIO | 2025-01-17 → 2024-12-27 (-21d) | 2025-02-06 → 2025-01-14 (-23d) | 18d → 19d | 10d → 0d |  | resources HH [144 h] → HH [152 h] |
| A8450 | GEOTEXTIL NO TEJIDO 400 G/M2, INC. COLOCACIÓN | 2025-01-20 → 2024-12-29 (-22d) | 2025-02-08 → 2025-01-16 (-23d) | 18d → 19d | 10d → 0d |  | resources HH [144 h] → HH [152 h] |
| A8460 | PERFILADO Y COMPACTACIÓN EN ZONA DE CORTE EN CORONA | 2025-01-22 → 2024-12-31 (-22d) | 2025-02-11 → 2025-01-18 (-24d) | 18d → 19d | 10d → 0d |  | resources HH [144 h] → HH [152 h] |
| A8470 | CONFORMACIÓN DE MATERIAL GRANULAR EN CORONA DE DIQUE | 2025-01-24 → 2025-01-02 (-22d) | 2025-02-13 → 2025-01-20 (-24d) | 18d → 19d | 10d → 0d |  | resources HH [144 h] → HH [152 h] |
| A8480 | COLOCACION Y ACOMODO DE ROCA EN UÑA DE DIQUE | 2025-01-27 → 2025-01-04 (-23d) | 2025-02-15 → 2025-01-22 (-24d) | 18d → 19d | 10d → 0d |  | resources HH [144 h] → HH [152 h] |
| A8490 | COLOCACION Y ACOMODO DE ROCA EN TALUD DE DIQUE | 2025-01-29 → 2025-01-06 (-23d) | 2025-02-18 → 2025-01-24 (-25d) | 18d → 19d | 10d → 0d |  | resources HH [144 h] → HH [152 h] |
| 11 | **DIQUE A2-D-1** | 2024-05-06 → 2024-04-18 (-18d) | 2025-01-09 → 2024-12-20 (-20d) |  |  |  |  |
| 10 | **DIQUE DE TIERRA COMPACTADA A2-D-01 SIN AFECTACION** | 2024-05-06 → 2024-04-18 (-18d) | 2024-08-30 → 2024-07-28 (-33d) |  |  |  |  |
| A8890 | ENTREGA DE TERRENO | 2024-05-06 → 2024-04-18 (-18d) | 2024-05-06 → 2024-04-18 (-18d) |  |  |  |  |
| A8900 | EXCAVACIÓN EN TERRENO NATURAL CON EQUIPO | 2024-05-07 → 2024-04-19 (-18d) | 2024-08-20 → 2024-07-18 (-33d) |  |  |  |  |
| A8910 | PERFILADO EN ZONA DE CORTE TALUD DE DIQUE | 2024-05-07 → 2024-04-20 (-17d) | 2024-08-20 → 2024-07-19 (-32d) |  | 1d → 0d | A8900 SS → A8900 SS+1d |  |
| A8920 | EXCAVACIÓN DE UÑA CON EQUIPO | 2024-05-08 → 2024-04-20 (-18d) | 2024-08-21 → 2024-07-19 (-33d) |  | 0d → 1d |  |  |
| A8930 | PREPARACIÓN DE FUNDACIÓN DE CUERPO DE DIQUE | 2024-05-09 → 2024-04-21 (-18d) | 2024-08-22 → 2024-07-20 (-33d) |  | 0d → 1d |  |  |
| A8940 | PEDRAPLEN e=60 cm | 2024-05-09 → 2024-04-22 (-17d) | 2024-08-22 → 2024-07-21 (-32d) |  | 1d → 0d |  |  |

| ID | Task | Start | Finish | Duration | Total float | Predecessors | Other |
| --- | --- | --- | --- | --- | --- | --- | --- |
| A8950 | PEDRAPLEN e=30 cm | 2024-05-09 → 2024-04-23 (-16d) | 2024-08-22 → 2024-07-22 (-31d) |  | 1d → 0d | A8940 FF → A8940 FF+1d |  |
| A8960 | CONFORMACIÓN DE CUERPO DE DIQUE CON MATERIAL PROPIO | 2024-05-10 → 2024-04-23 (-17d) | 2024-08-23 → 2024-07-22 (-32d) |  |  |  |  |
| A8970 | CONFORMACIÓN DE RELLENO NO ESTRUCTURAL CON MATERIAL PROPIO | 2024-05-11 → 2024-04-24 (-17d) | 2024-08-24 → 2024-07-23 (-32d) |  |  |  |  |
| A8980 | GEOTEXTIL NO TEJIDO 400 G/M2, INC. COLOCACIÓN | 2024-05-13 → 2024-04-25 (-18d) | 2024-08-26 → 2024-07-24 (-33d) |  |  |  |  |
| A8990 | PERFILADO Y COMPACTACIÓN EN ZONA DE CORTE EN CORONA | 2024-05-14 → 2024-04-26 (-18d) | 2024-08-27 → 2024-07-25 (-33d) |  |  |  |  |
| A9000 | CONFORMACIÓN DE MATERIAL GRANULAR EN CORONA DE DIQUE | 2024-05-15 → 2024-04-27 (-18d) | 2024-08-28 → 2024-07-26 (-33d) |  |  |  |  |
| A9010 | COLOCACION Y ACOMODO DE ROCA EN UÑA DE DIQUE | 2024-05-16 → 2024-04-28 (-18d) | 2024-08-29 → 2024-07-27 (-33d) |  |  |  |  |
| A9020 | COLOCACION Y ACOMODO DE ROCA EN TALUD DE DIQUE | 2024-05-17 → 2024-04-29 (-18d) | 2024-08-30 → 2024-07-28 (-33d) |  |  |  |  |
| 4 | **DIQUE DE TIERRA COMPACTADA A2-D-01 CON AFECTACION** | 2024-10-08 → 2024-09-15 (-23d) | 2024-11-14 → 2024-10-17 (-28d) |  |  |  |  |
| A9030 | ENTREGA DE TERRENO | 2024-10-08 → 2024-09-15 (-23d) | 2024-10-08 → 2024-09-15 (-23d) |  |  | A8380 → A8160 |  |
| A9040 | EXCAVACIÓN EN TERRENO NATURAL CON EQUIPO | 2024-10-09 → 2024-09-16 (-23d) | 2024-10-29 → 2024-10-03 (-26d) |  |  |  |  |
| A9050 | EXCAVACIÓN DE UÑA CON EQUIPO | 2024-10-10 → 2024-09-17 (-23d) | 2024-10-30 → 2024-10-04 (-26d) |  |  |  |  |
| A9060 | PERFILADO EN ZONA DE CORTE TALUD DE DIQUE | 2024-10-11 → 2024-09-18 (-23d) | 2024-10-31 → 2024-10-05 (-26d) |  |  |  |  |
| A9070 | PREPARACIÓN DE FUNDACIÓN DE CUERPO DE DIQUE | 2024-10-11 → 2024-09-18 (-23d) | 2024-10-31 → 2024-10-05 (-26d) |  |  |  |  |
| A9090 | PEDRAPLEN e=60 cm | 2024-10-14 → 2024-09-20 (-24d) | 2024-11-02 → 2024-10-07 (-26d) |  |  |  |  |
| A9080 | CONFORMACIÓN DE CUERPO DE DIQUE CON MATERIAL PROPIO | 2024-10-16 → 2024-09-22 (-24d) | 2024-11-05 → 2024-10-09 (-27d) |  |  |  |  |
| A9100 | PEDRAPLEN e=30 cm | 2024-10-16 → 2024-09-22 (-24d) | 2024-11-05 → 2024-10-09 (-27d) |  |  |  |  |
| A9110 | CONFORMACIÓN DE RELLENO NO ESTRUCTURAL CON MATERIAL PROPIO | 2024-10-18 → 2024-09-24 (-24d) | 2024-11-07 → 2024-10-11 (-27d) |  |  |  |  |
| A9120 | GEOTEXTIL NO TEJIDO 400 G/M2, INC. COLOCACIÓN | 2024-10-21 → 2024-09-26 (-25d) | 2024-11-09 → 2024-10-13 (-27d) |  |  |  |  |
| A9130 | PERFILADO Y COMPACTACIÓN EN ZONA DE CORTE EN CORONA | 2024-10-22 → 2024-09-27 (-25d) | 2024-11-11 → 2024-10-14 (-28d) |  |  |  |  |
| A9140 | CONFORMACIÓN DE MATERIAL GRANULAR EN CORONA DE DIQUE | 2024-10-23 → 2024-09-28 (-25d) | 2024-11-12 → 2024-10-15 (-28d) |  |  |  |  |
| A9150 | COLOCACION Y ACOMODO DE ROCA EN UÑA DE DIQUE | 2024-10-24 → 2024-09-29 (-25d) | 2024-11-13 → 2024-10-16 (-28d) |  |  |  |  |
| A9160 | COLOCACION Y ACOMODO DE ROCA EN TALUD DE DIQUE | 2024-10-25 → 2024-09-30 (-25d) | 2024-11-14 → 2024-10-17 (-28d) |  |  |  |  |
| 5 | **DIQUE DE TIERRA COMPACTADA A2-D-01 POR LIBERAR** | 2024-11-15 → 2024-10-18 (-28d) | 2025-01-09 → 2024-12-20 (-20d) |  |  |  |  |
| A9180 | ENTREGA DE TERRENO | 2024-11-15 → 2024-10-18 (-28d) | 2024-11-15 → 2024-10-18 (-28d) |  |  |  |  |
| A9170 | EXCAVACIÓN EN TERRENO NATURAL CON EQUIPO | 2024-11-16 → 2024-10-19 (-28d) | 2024-12-25 → 2024-12-08 (-17d) | 34d → 51d |  |  | resources HH [272 h] → HH [408 h] |
| A9200 | PERFILADO EN ZONA DE CORTE TALUD DE DIQUE | 2024-11-16 → 2024-10-20 (-27d) | 2024-12-25 → 2024-12-09 (-16d) | 34d → 51d |  | A9170 SS → A9170 SS+1d | resources HH [272 h] → HH [408 h] |
| A9190 | EXCAVACIÓN DE UÑA CON EQUIPO | 2024-11-18 → 2024-10-21 (-28d) | 2024-12-26 → 2024-12-10 (-16d) | 34d → 51d |  | A9170 SS+1d → A9170 SS+2d | resources HH [272 h] → HH [408 h] |
| A9220 | PEDRAPLEN e=60 cm | 2024-11-19 → 2024-10-22 (-28d) | 2024-12-27 → 2024-12-11 (-16d) | 34d → 51d |  |  | resources HH [272 h] → HH [408 h] |
| A9210 | PREPARACIÓN DE FUNDACIÓN DE CUERPO DE DIQUE | 2024-11-20 → 2024-10-23 (-28d) | 2024-12-28 → 2024-12-12 (-16d) | 34d → 51d |  |  | resources HH [272 h] → HH [408 h] |
| A9230 | PEDRAPLEN e=30 cm | 2024-11-21 → 2024-10-24 (-28d) | 2024-12-30 → 2024-12-13 (-17d) | 34d → 51d |  |  | resources HH [272 h] → HH [408 h] |
| A9240 | CONFORMACIÓN DE CUERPO DE DIQUE CON MATERIAL PROPIO | 2024-11-21 → 2024-10-24 (-28d) | 2024-12-30 → 2024-12-13 (-17d) | 34d → 51d |  |  | resources HH [272 h] → HH [408 h] |
| A9250 | CONFORMACIÓN DE RELLENO NO ESTRUCTURAL CON MATERIAL PROPIO | 2024-11-23 → 2024-10-26 (-28d) | 2025-01-01 → 2024-12-15 (-17d) | 34d → 51d |  |  | resources HH [272 h] → HH [408 h] |
| A9260 | GEOTEXTIL NO TEJIDO 400 G/M2, INC. COLOCACIÓN | 2024-11-25 → 2024-10-27 (-29d) | 2025-01-02 → 2024-12-16 (-17d) | 34d → 51d |  |  | resources HH [272 h] → HH [408 h] |
| A9270 | PERFILADO Y COMPACTACIÓN EN ZONA DE CORTE EN CORONA | 2024-11-26 → 2024-10-28 (-29d) | 2025-01-03 → 2024-12-17 (-17d) | 34d → 51d |  |  | resources HH [272 h] → HH [408 h] |
| A9280 | CONFORMACIÓN DE MATERIAL GRANULAR EN CORONA DE DIQUE | 2024-11-27 → 2024-10-29 (-29d) | 2025-01-04 → 2024-12-18 (-17d) | 34d → 51d |  |  | resources HH [272 h] → HH [408 h] |
| A9290 | COLOCACION Y ACOMODO DE ROCA EN UÑA DE DIQUE | 2024-11-28 → 2024-10-30 (-29d) | 2025-01-06 → 2024-12-19 (-18d) | 34d → 51d |  |  | resources HH [272 h] → HH [408 h] |
| A9300 | COLOCACION Y ACOMODO DE ROCA EN TALUD DE DIQUE | 2024-11-29 → 2024-10-31 (-29d) | 2025-01-09 → 2024-12-20 (-20d) | 36d → 51d |  |  | resources HH [288 h] → HH [408 h] |
| 2 | **OBRAS DE ARTE** | 2024-02-27 → 2024-04-18 (+51d) | 2025-03-01 → 2025-02-28 (-1d) |  |  |  |  |
| 1 | **CAPTACIÓN** | 2024-02-27 → 2024-04-18 (+51d) | 2025-02-28 → 2025-02-27 (-1d) |  |  |  |  |
| A7240 | Construccion de Captaciones | 2024-02-27 → 2024-04-18 (+51d) | 2025-02-28 → 2025-02-27 (-1d) |  | 0d → 1d | A7470 → A7880 |  |
| 3 | **RETORNO A2-OA-RE-I-11-25** | 2024-03-09 → 2024-04-28 (+50d) | 2025-02-28 → 2025-02-27 (-1d) |  |  |  |  |
| A7250 | Construccion de Retorno | 2024-03-09 → 2024-04-28 (+50d) | 2025-02-28 → 2025-02-27 (-1d) |  | 0d → 1d |  |  |
| 2 | **RETORNOS Q=100 A 1000 l/s** | 2024-03-21 → 2024-05-08 (+48d) | 2025-02-28 → 2025-02-27 (-1d) |  |  |  |  |
| A7260 | Construccion de Retorno | 2024-03-21 → 2024-05-08 (+48d) | 2025-02-28 → 2025-02-27 (-1d) |  | 0d → 1d |  |  |
| 4 | **REPOSICIÓN DE CANALES** | 2024-04-02 → 2024-05-18 (+46d) | 2025-03-01 → 2025-02-28 (-1d) |  |  |  |  |
| A7270 | Reposicion de Canales | 2024-04-02 → 2024-05-18 (+46d) | 2025-03-01 → 2025-02-28 (-1d) |  | 0d → 1d |  |  |
| 5 | **TRANSPORTES** | 2023-12-07 → 2023-12-08 (+1d) |  |  |  |  |  |
| 1 | **TRANSPORTES** | 2023-12-07 → 2023-12-08 (+1d) |  |  |  |  |  |
| A7220 | TRANSPORTE DE MATERIAL EXCEDENTE PARA DISTANCIAS <1KM | 2023-12-07 → 2023-12-08 (+1d) |  | 387d → 450d |  |  | resources HH [3096 h] → HH [3600 h] |
| A7230 | TRANSPORTE DE MATERIAL EXCEDENTE PARA DISTANCIAS >1KM | 2023-12-07 → 2023-12-08 (+1d) |  | 387d → 450d |  |  | resources HH [3096 h] → HH [3600 h] |
| A7170 | TRANSPORTE DE MATERIAL GRANULAR PARA DISTANCIAS <1KM | 2023-12-08 → 2023-12-14 (+6d) |  | 386d → 444d |  |  | resources HH [3088 h] → HH [3552 h] |
| A7190 | TRANSPORTE DE MATERIAL GRANULAR PARA DISTANCIAS >1KM | 2023-12-08 → 2023-12-14 (+6d) |  | 386d → 444d |  |  | resources HH [3088 h] → HH [3552 h] |
| A7200 | TRANSPORTE DE ROCA PARA DISTANCIAS <1KM | 2023-12-29 → 2024-01-02 (+4d) |  | 368d → 425d |  |  | resources HH [2944 h] → HH [3400 h] |
| A7210 | TRANSPORTE DE ROCA PARA DISTANCIAS >1KM | 2023-12-29 → 2024-01-02 (+4d) |  | 368d → 425d |  |  | resources HH [2944 h] → HH [3400 h] |
| 3 | **ARQUITECTURA Y PAISAJISMO** | 2024-11-16 → 2024-11-10 (-6d) | 2024-12-30 → 2024-12-17 (-13d) |  |  |  |  |
| 1 | **OBRAS PRELIMINARES** | 2024-11-16 → 2024-11-10 (-6d) | 2024-11-21 → 2024-11-14 (-7d) |  |  |  |  |
| A3860 | Obras Preliminares | 2024-11-16 → 2024-11-10 (-6d) | 2024-11-21 → 2024-11-14 (-7d) |  | 53d → 74d | A9170 SS → A9170 SS+22d |  |
| 2 | **MOVIMIENTO DE TIERRAS** | 2024-11-16 → 2024-11-10 (-6d) | 2024-12-26 → 2024-12-14 (-12d) |  |  |  |  |
| A3890 | Movimiento de Tierras | 2024-11-16 → 2024-11-10 (-6d) | 2024-12-26 → 2024-12-14 (-12d) |  | 53d → 74d |  |  |
| 3 | **PAVIMENTOS, RECUBRIMIENTOS Y BORDILLOS** | 2024-11-28 → 2024-11-20 (-8d) | 2024-12-30 → 2024-12-17 (-13d) |  |  |  |  |
| A3930 | Pavimientos, Recubrimientos y Bordillos | 2024-11-28 → 2024-11-20 (-8d) | 2024-12-30 → 2024-12-17 (-13d) |  | 53d → 74d |  |  |
| 4 | **MOBILIARIOS, BARANDAS Y ESCALERAS** | 2024-12-04 → 2024-11-25 (-9d) | 2024-12-30 → 2024-12-17 (-13d) |  |  |  |  |
| A4000 | Instalacion de Moviliarios, Barandas y escaleras | 2024-12-04 → 2024-11-25 (-9d) | 2024-12-30 → 2024-12-17 (-13d) |  | 53d → 74d |  |  |
| 4 | **PROGRAMA DE CIERRE DE OBRA** | 2023-12-05 → 2023-12-04 (-1d) |  |  |  |  |  |
| A1790 | ACONDICIONAMIENTO DE DEPOSITOS DE MATERIALES EXCEDENTES (DME) | 2023-12-05 → 2023-12-04 (-1d) | 2025-02-21 → 2025-02-22 (+1d) | 382d → 447d |  |  | resources HH [3056 h] → none |
| A1780 | RESTAURACIÓN DE ÁREAS DE INSTALACIONES PROVISIONALES | 2025-02-22 → 2025-02-23 (+1d) |  |  |  |  |  |
